# NATURA CORDOBA-PROJECT

Schedule from MS Project, 2010-05-27 to 2010-07-11.
Contract

## Calendars

- Estándar: Mon-Sun 09:00-13:00, 15:00-19:00. Exceptions (off unless hours are given): 2010-05-29 to 2010-05-30 09:00-13:00, 15:00-19:00, 2010-06-05 to 2010-06-06 09:00-13:00, 15:00-19:00, 2010-06-12 to 2010-06-13 09:00-13:00, 15:00-19:00, 2010-06-19 to 2010-06-20 09:00-13:00, 15:00-19:00, 2010-06-26 to 2010-06-27 09:00-13:00, 15:00-19:00, 2010-07-03 09:00-13:00, 15:00-19:00, 2010-07-10 09:00-13:00, 15:00-19:00.

## Schedule

| ID | WBS | Task | Duration | Start | Finish | Predecessors | Total slack | Free slack | Constraint |
| --- | --- | --- | --- | --- | --- | --- | --- | --- | --- |
| 1 | 1 | **NATURA** | 46d | 2010-05-27 | 2010-07-11 |  | 0d |  |  |
| 2 | 1.1 | **PRELIMINARES** | 44d | 2010-05-27 | 2010-07-09 |  | 4d |  |  |
| 3 | 1.1.1 | Replanteo | 1d | 2010-05-31 | 2010-05-31 |  | 0d |  | start no earlier than 2010-05-31 |
| 4 | 1.1.2 | Protecciones para interiores ( nylon y cartón corrugado ) | 40d | 2010-05-31 | 2010-07-09 | 3SS | 2d |  |  |
| 5 | 1.1.3 | Programa de seguridad e higiene | 4d | 2010-05-27 | 2010-05-30 |  | 36d | 0d | start no earlier than 2010-05-27 |
| 6 | 1.1.4 | Elementos de proteccion, matafuegos | 1d | 2010-05-31 | 2010-05-31 | 3SS | 41d |  |  |
| 7 | 1.1.5 | Luz y tablero de obra | 1d | 2010-05-31 | 2010-05-31 | 3SS | 41d |  |  |
| 8 | 1.2 | **COMPRAS NATURA (a cargo de NATURA)** | 40d | 2010-05-31 | 2010-07-09 |  | 0d |  |  |
| 9 | 1.2.1 | Compra de equipamiento de oficinas | 30d | 2010-05-31 | 2010-06-29 | 3SS | 0d |  | start no earlier than 2010-05-31 |
| 10 | 1.2.2 | Compra paneles moviles | 30d | 2010-05-31 | 2010-06-29 | 3SS | 7d | 0d | start no earlier than 2010-05-31 |
| 11 | 1.2.3 | Compra de muebles especiales | 40d | 2010-05-31 | 2010-07-09 | 3SS | 2d |  | start no earlier than 2010-05-31 |
| 12 | 1.3 | **COMPRAS CONTRATISTA** | 34d | 2010-05-27 | 2010-06-29 |  | 15d |  |  |
| 13 | 1.3.1 | Compra porcelanato | 10d | 2010-05-27 | 2010-06-05 | 5SS | 36d |  |  |
| 14 | 1.3.2 | Compra de cortinas | 30d | 2010-05-31 | 2010-06-29 | 3SS | 9d | 0d |  |
| 15 | 1.3.3 | Compra de equipos de aire acondicionado | 30d | 2010-05-31 | 2010-06-29 | 14SS | 9d | 0d | start no earlier than 2010-04-20 |
| 16 | 1.4 | **DEMOLICIONES** | 5d | 2010-05-31 | 2010-06-04 |  | 40d |  |  |
| 17 | 1.4.1 | Demolicion de solado existente | 1d | 2010-05-31 | 2010-05-31 |  | 41d |  |  |
| 18 | 1.4.2 | Demomicion de cielorraso entrepiso | 3d | 2010-05-31 | 2010-06-02 |  | 39d |  |  |
| 19 | 1.4.3 | Desamure de cañerias vacias obsoletas para instalaciones electricas | 5d | 2010-05-31 | 2010-06-04 |  | 37d |  |  |
| 20 | 1.4.4 | Picado de pared para reubicacion de instalaciones termomecanicas | 5d | 2010-05-31 | 2010-06-04 |  | 37d |  |  |
| 21 | 1.4.5 | Desarme de cielorraso hall de ascensores para pasaje de cañeria de equipos de aire acondicionado | 4d | 2010-05-31 | 2010-06-03 |  | 38d |  |  |
| 22 | 1.5 | **ALBAÑILERIA** | 10d | 2010-05-31 | 2010-06-09 |  | 16d |  |  |
| 23 | 1.5.1 | Reparación de revoques interiores por ejecucion de canalizaciones para instalaciones electricas | 3d | 2010-05-31 | 2010-06-02 |  | 39d |  |  |
| 24 | 1.5.2 | Reparación de revoques interiores por ejecucion de canalizaciones para instalaciones de aire acondicionado | 2d | 2010-05-31 | 2010-06-01 |  | 36d | 0d |  |
| 25 | 1.5.3 | Reparacion de carpeta | 2d | 2010-06-04 | 2010-06-05 | 24FS+2d | 36d |  |  |
| 26 | 1.5.4 | Instalación de porcelanato idem existente | 3d | 2010-05-31 | 2010-06-02 |  | 39d |  |  |
| 27 | 1.5.5 | Transporte de materiales por escaleras | 3d | 2010-05-31 | 2010-06-02 |  | 13d | 0d |  |
| 28 | 1.5.6 | Ayuda de gremios para instalaciones eléctricas y de aire acondicionado | 4d | 2010-06-06 | 2010-06-09 | 68 | 32d |  |  |

| ID | WBS | Task | Duration | Start | Finish | Predecessors | Total slack | Free slack |
| --- | --- | --- | --- | --- | --- | --- | --- | --- |
| 29 | 1.6 | **TABIQUES EN PLACAS DE ROCA DE YESO** | 10d | 2010-06-04 | 2010-06-13 |  | 27d |  |
| 30 | 1.6.1 | Estructura compuesta por montante y solera | 10d | 2010-06-04 | 2010-06-13 | 52FS-1d | 28d | 0d |
| 31 | 1.6.2 | Emplacado una cara | 5d | 2010-06-05 | 2010-06-09 | 30SS+1d | 30d | 0d |
| 32 | 1.6.3 | Aislacion acustica | 2d | 2010-06-10 | 2010-06-11 | 31 | 30d |  |
| 33 | 1.6.4 | Emplacado segunda cara | 3d | 2010-06-07 | 2010-06-09 | 70 | 17d | 0d |
| 34 | 1.6.5 | Masillado, cantoneras, terminaciones | 4d | 2010-06-10 | 2010-06-13 | 33 | 28d |  |
| 35 | 1.7 | **CIELORRASO EN PLACAS DE ROCA DE YESO** | 9d | 2010-06-04 | 2010-06-12 |  | 20d |  |
| 36 | 1.7.1 | Estructura cielorraso | 5d | 2010-06-04 | 2010-06-08 | 30SS | 33d |  |
| 37 | 1.7.2 | Emplacado una cara | 3d | 2010-06-07 | 2010-06-09 | 65FS-2d | 14d | 0d |
| 38 | 1.7.3 | Masillado, cantoneras, terminaciones | 3d | 2010-06-10 | 2010-06-12 | 37 | 14d | 0d |
| 39 | 1.8 | **ZOCALOS** | 3d | 2010-06-25 | 2010-06-27 |  | 17d |  |
| 40 | 1.8.1 | Colocacion de zocalo de madera | 3d | 2010-06-25 | 2010-06-27 | 44 | 14d |  |
| 41 | 1.9 | **PINTURA** | 16d | 2010-06-09 | 2010-06-24 |  | 20d |  |
| 42 | 1.9.1 | Enduido y lijado de superficie de tabiques y muros | 5d | 2010-06-09 | 2010-06-13 | 33FS-1d | 17d | 0d |
| 43 | 1.9.2 | Enduido y lijado de superficie de cielorrasos | 5d | 2010-06-12 | 2010-06-16 | 38FS-1d | 25d |  |
| 44 | 1.9.3 | Aplicación de latex para tabiques | 7d | 2010-06-18 | 2010-06-24 | 45SS+4d | 14d | 0d |
| 45 | 1.9.4 | Aplicación de latex para cielorrasos | 7d | 2010-06-14 | 2010-06-20 | 38FS+1d | 14d | 0d |
| 46 | 1.9.5 | Esmalte sintetico para puertas interiores y barandas | 10d | 2010-06-14 | 2010-06-23 | 45SS | 18d |  |
| 47 | 1.9.6 | Esmalte sintetico para zocalos | 3d | 2010-06-13 | 2010-06-15 | 57FS-2d | 26d |  |
| 48 | 1.10 | **CRISTALES Y ESPEJOS** | 4d | 2010-06-14 | 2010-06-17 |  | 17d |  |
| 49 | 1.10.1 | Provisión e instalación de frentes de cristal templado | 2d | 2010-06-14 | 2010-06-15 | 42 | 17d | 0d |
| 50 | 1.10.2 | Provisión e instalación de puerta de cristal templado | 2d | 2010-06-16 | 2010-06-17 | 49 | 24d |  |
| 51 | 1.11 | **HERRERIA** | 6d | 2010-05-31 | 2010-06-05 |  | 31d |  |
| 52 | 1.11.1 | Colocacion de refuerzos tubulares para muebles | 5d | 2010-05-31 | 2010-06-04 | 27SS | 28d | 0d |
| 53 | 1.11.2 | Refuerzos carpinterias | 1d | 2010-06-05 | 2010-06-05 | 52 | 36d |  |

| ID | WBS | Task | Duration | Start | Finish | Predecessors | Total slack | Free slack | Constraint |
| --- | --- | --- | --- | --- | --- | --- | --- | --- | --- |
| 54 | 1.12 | **DIVISORES MOVILES (a cargo de NATURA)** | 2d | 2010-06-30 | 2010-07-01 |  | 10d |  |  |
| 55 | 1.12.1 | Instalación de paneles decibel | 2d | 2010-06-30 | 2010-07-01 | 10 | 7d | 0d |  |
| 56 | 1.13 | **ZOCALOS Y SOLIAS** | 5d | 2010-06-10 | 2010-06-14 |  | 29d |  |  |
| 57 | 1.13.1 | Colocacion de Zocalos de MDF para pintar | 5d | 2010-06-10 | 2010-06-14 | 33 | 26d | 0d |  |
| 58 | 1.14 | **PUERTAS** | 2d | 2010-06-19 | 2010-06-20 |  | 24d |  |  |
| 59 | 1.14.1 | Provision e instalacion de puertas interiores | 2d | 2010-06-19 | 2010-06-20 | 42SS+10d | 21d |  |  |
| 60 | 1.15 | **INSTALACIÓN SANITARIA** | 2d | 2010-05-31 | 2010-06-01 |  | 43d |  |  |
| 61 | 1.15.1 | Ajsute de instalación para equipos de aire acondicionado | 2d | 2010-05-31 | 2010-06-01 |  | 40d |  |  |
| 62 | 1.16 | **INSTALACIÓN ELECTRICA** | 29d | 2010-05-31 | 2010-06-28 |  | 16d |  |  |
| 63 | 1.16.1 | Alimentación tableros | 5d | 2010-05-31 | 2010-06-04 |  | 37d |  |  |
| 64 | 1.16.2 | Readecuacion de instalación existente | 10d | 2010-05-31 | 2010-06-09 |  | 32d |  |  |
| 65 | 1.16.3 | Canalizaciones para bocas de iluminacion | 6d | 2010-06-03 | 2010-06-08 | 27 | 13d | 0d |  |
| 66 | 1.16.4 | Cableado de bocas de iluminación común y emergencia | 3d | 2010-06-19 | 2010-06-21 | 65FS+10d | 13d | 0d |  |
| 67 | 1.16.5 | Instalación de artefactos de iluminación común | 4d | 2010-06-24 | 2010-06-27 |  | 13d | 0d | start no earlier than 2010-06-24 |
| 68 | 1.16.6 | Canalizaciones para puestos | 2d | 2010-06-04 | 2010-06-05 | 65SS+1d | 32d | 0d |  |
| 69 | 1.16.7 | Instalación de artefactos iluminación emergencias | 1d | 2010-06-28 | 2010-06-28 | 67 | 13d |  |  |
| 70 | 1.16.8 | Canalizacion efectos de iluminacion | 2d | 2010-06-05 | 2010-06-06 | 65SS+2d | 17d | 0d |  |
| 71 | 1.16.9 | Tableros de iluminación | 4d | 2010-06-22 | 2010-06-25 | 66 | 13d | 0d |  |
| 72 | 1.16.10 | Tablero de AA | 3d | 2010-06-26 | 2010-06-28 | 71 | 13d |  |  |
| 73 | 1.16.11 | Alimentadores equipos interiores | 3d | 2010-05-31 | 2010-06-02 |  | 39d |  |  |
| 74 | 1.16.12 | Tendido circuito eléctrico reforzado para microondas y/o expendedoras | 3d | 2010-05-31 | 2010-06-02 |  | 39d |  |  |
| 75 | 1.17 | **ARTEFACTOS DE ILUMINACION** | 1d | 2010-06-25 | 2010-06-25 |  | 19d |  |  |
| 76 | 1.17.1 | Provision de artefactos | 1d | 2010-06-25 | 2010-06-25 | 67SS+1d | 16d |  |  |
| 77 | 1.18 | **INSTALACIÓN DE AIRE ACONDICIONADO Y CALEFACCION** | 30d | 2010-06-03 | 2010-07-02 |  | 12d |  |  |
| 78 | 1.18.1 | Instalación de unidades interiores | 3d | 2010-06-21 | 2010-06-23 | 45 | 16d | 0d |  |
| 79 | 1.18.2 | Instalación de unidades exteriores | 3d | 2010-06-30 | 2010-07-02 | 15 | 9d |  |  |
| 80 | 1.18.3 | Vinculación entre unidades condensadoras exteriores e interiores | 3d | 2010-06-03 | 2010-06-05 | 65SS | 36d |  |  |
| 81 | 1.18.4 | Puesta en marcha, regulación y control de funcionamiento | 2d | 2010-06-24 | 2010-06-25 | 78 | 16d |  |  |

| ID | WBS | Task | Duration | Start | Finish | Predecessors | Total slack | Constraint |
| --- | --- | --- | --- | --- | --- | --- | --- | --- |
| 82 | 1.19 | **MUEBLES ESPECIALES** | 7d | 2010-07-05 | 2010-07-11 |  | 0d |  |
| 83 | 1.19.1 | instalación de muebles | 7d | 2010-07-05 | 2010-07-11 | 9FS+5d | 0d |  |
| 84 | 1.20 | **CORTINAS** | 2d | 2010-07-07 | 2010-07-08 |  | 3d |  |
| 85 | 1.20.1 | instalación de cortinas | 2d | 2010-07-07 | 2010-07-08 | 83SS+2d | 3d |  |
| 86 | 1.21 | **GRAFICA Y VINILOS** | 1d | 2010-06-24 | 2010-06-24 |  | 17d |  |
| 87 | 1.21.1 | Provision e instalación de vinilos | 1d | 2010-06-24 | 2010-06-24 | 49SS+10d | 17d |  |
| 88 | 1.22 | **LIMPIEZA DE OBRA** | 40d | 2010-05-31 | 2010-07-09 |  | 2d |  |
| 89 | 1.22.1 | Limpieza de obra diaria | 40d | 2010-05-31 | 2010-07-09 | 3SS | 2d |  |
| 90 | 1.22.2 | Limpieza de obra final | 5d | 2010-06-30 | 2010-07-04 | 55SS | 7d |  |
| 91 | 1.22.3 | Alquiler y carga de volquetes | 3d | 2010-06-10 | 2010-07-01 |  | 10d | start no earlier than 2010-06-10 |
