# proyect mc donals

Schedule from MS Project, 2013-10-28 to 2014-02-05.

## Calendars

- CORRIDO: Mon-Sun 09:00-13:00, 15:00-19:00. Exceptions (off unless hours are given): 2014-01-01.

## Schedule

| ID | WBS | Task | Duration | Start | Finish | Predecessors | Total slack | Free slack | Constraint |
| --- | --- | --- | --- | --- | --- | --- | --- | --- | --- |
| 1 | 1 | **OBRA JUST PEOPLE** | 100d | 2013-10-28 | 2014-02-05 |  | 0d |  |  |
| 2 | 1.1 | **OBRA: Habilitacion Cliente In People** | 100d | 2013-10-28 | 2014-02-05 |  | 0d |  |  |
| 3 | 1.1.1 | **INICIO DE OBRA** | 24d | 2013-10-28 | 2013-11-20 |  | 0d |  |  |
| 4 | 1.1.1.1 | Demolicion de losa para escalera | 3d | 2013-10-29 | 2013-10-31 | 7 | 69d | 0d |  |
| 5 | 1.1.1.2 | Picado y retiro de sobre losa existente( 2 piso ) | 3d | 2013-11-12 | 2013-11-14 | 7FS+14d | 0d |  | start no earlier than 2013-10-28 |
| 6 | 1.1.1.3 | sobrelosa nueva ( 2 piso) | 4d | 2013-11-14 | 2013-11-17 | 5FS-1d | 0d |  |  |
| 7 | 1.1.1.4 | Instalación de faena | 1d | 2013-10-28 | 2013-10-28 |  | 0d |  |  |
| 8 | 1.1.1.5 | Elementos de proteccion hall de acceso y asencor | 1d | 2013-10-29 | 2013-10-29 | 7 | 98d |  |  |
| 9 | 1.1.1.6 | Trazado | 2d | 2013-11-19 | 2013-11-20 | 6FS+1d | 0d |  |  |
| 10 | 1.1.2 | **ESCALAS** | 36d | 2013-11-16 | 2013-12-21 |  | 45d |  |  |
| 11 | 1.1.2.1 | Escalera metalica con peldaños de hormigon pulido, baranda de fierro para revestir | 12d | 2013-11-16 | 2013-11-27 | 4FS+15d | 69d |  | start no earlier than 2013-10-18 |
| 12 | 1.1.2.2 | Graderias de hormigon liviano en Foyer, sujeto a calculo | 5d | 2013-12-17 | 2013-12-21 | 18FS-2d | 45d |  | start no earlier than 2013-10-23 |
| 13 | 1.1.3 | **TABIQUES , VIGAS Y CIELO** | 49d | 2013-11-21 | 2014-01-09 |  | 0d |  |  |
| 14 | 1.1.3.1 | **Tabiques** | 28d | 2013-11-21 | 2013-12-18 |  | 0d |  |  |
| 15 | 1.1.3.1.1 | Estructura Tabiques | 11d | 2013-11-21 | 2013-12-01 | 9, 6FS-7d | 0d |  |  |
| 16 | 1.1.3.1.2 | Emplacado 1ª cara | 12d | 2013-11-30 | 2013-12-11 | 15FS-2d | 0d |  |  |
| 17 | 1.1.3.1.3 | Aislación en tabiques | 3d | 2013-12-11 | 2013-12-13 | 16FS-1d | 53d |  |  |
| 18 | 1.1.3.1.4 | Emplacado 2ª cara | 8d | 2013-12-11 | 2013-12-18 | 68FS-3d, 16FS-1d | 0d |  |  |
| 19 | 1.1.3.2 | **Vigas Volcometal** | 17d | 2013-12-07 | 2013-12-23 |  | 0d |  |  |
| 20 | 1.1.3.2.1 | Estructura dinteles, vigas y cenefas | 6d | 2013-12-07 | 2013-12-12 | 15FS+5d | 6d |  |  |
| 21 | 1.1.3.2.2 | Emplacado de dinteles,vigas y cenefas | 5d | 2013-12-19 | 2013-12-23 | 20, 18 | 0d |  |  |
| 22 | 1.1.3.3 | **Cielo** | 11d | 2013-12-29 | 2014-01-09 |  | 0d |  |  |
| 23 | 1.1.3.3.1 | **Cielo duro** | 11d | 2013-12-29 | 2014-01-09 |  | 0d |  |  |
| 24 | 1.1.3.3.1.1 | Estructura Cielo Duro | 5d | 2013-12-29 | 2014-01-03 | 15FS+2d, 88, 89, 90 | 0d |  |  |
| 25 | 1.1.3.3.1.2 | Emplacado Cielo duro | 7d | 2014-01-03 | 2014-01-09 | 24FS-1d, 69, 18FS-1d | 0d |  |  |

| ID | WBS | Task | Type | Duration | Start | Finish | Predecessors | Total slack | Free slack | Constraint |
| --- | --- | --- | --- | --- | --- | --- | --- | --- | --- | --- |
| 26 | 1.1.4 | **SANITARIOS** |  | 30d | 2013-12-10 | 2014-01-09 |  | 27d |  |  |
| 27 | 1.1.4.1 | Canalizacion y reubicacion de AP y alcantarillado |  | 10d | 2013-12-10 | 2013-12-19 | 15FS+8d | 38d | 11d | start no earlier than 2013-10-30 |
| 28 | 1.1.4.2 | Provision e Instalacion de artifactos |  | 6d | 2013-12-31 | 2014-01-06 | 31, 27 | 27d | 0d | start no earlier than 2013-12-09 |
| 29 | 1.1.4.3 | Provision e Instalacion de griferia |  | 4d | 2014-01-06 | 2014-01-09 | 28FS-1d | 27d |  |  |
| 30 | 1.1.5 | **PAVIMENTOS** |  | 26d | 2013-12-26 | 2014-01-21 |  | 13d |  |  |
| 31 | 1.1.5.1 | Instalación de ceramicos PISO |  | 5d | 2013-12-26 | 2013-12-30 | 18, 45FS-3d | 21d | 0d | start no earlier than 2013-04-01 |
| 32 | 1.1.5.2 | Instalacion de piso de madera |  | 5d | 2014-01-11 | 2014-01-15 | 18, 46 | 21d |  | start no earlier than 2013-11-20 |
| 33 | 1.1.5.3 | Instalacion de microfloor |  | 11d | 2014-01-09 | 2014-01-19 | 44FS-5d | 0d |  | start no earlier than 2013-12-01 |
| 34 | 1.1.5.4 | Llegada de alfombra a obra | milestone | 0d | 2014-01-14 | 2014-01-14 | 48FS-2d, 46 | 12d | 2d | finish no earlier than 2013-12-28 |
| 35 | 1.1.5.5 | Instalacion de alfombra |  | 6d | 2014-01-16 | 2014-01-21 | 34, 48 | 10d | 0d |  |
| 36 | 1.1.6 | **REVESTIMIENTO** |  | 18d | 2013-12-19 | 2014-01-06 |  | 30d |  |  |
| 37 | 1.1.6.1 | Instalacion de ceramicos modelo a definir |  | 3d | 2013-12-31 | 2014-01-03 | 31 | 22d | 0d | start no earlier than 2013-11-27 |
| 38 | 1.1.6.2 | Instalacion ceramicos tipo Cordoba |  | 3d | 2014-01-04 | 2014-01-06 | 37 | 30d |  | start no earlier than 2013-12-05 |
| 39 | 1.1.6.3 | Revestimiento acustico RA de tabiques |  | 3d | 2013-12-19 | 2013-12-21 | 18 | 45d |  | start no earlier than 2013-11-11 |
| 40 | 1.1.7 | **GUARDAPOLVOS** |  | 5d | 2014-01-21 | 2014-01-25 |  | 10d |  |  |
| 41 | 1.1.7.1 | Instalación de guardapolvo |  | 5d | 2014-01-21 | 2014-01-25 | 35FS-1d | 10d |  | start no earlier than 2014-01-04 |
| 42 | 1.1.8 | **PINTURA** |  | 42d | 2013-12-19 | 2014-01-30 |  | 0d |  |  |
| 43 | 1.1.8.1 | Preparacion de superficie tabiques nuevos. Considera huincha pasta y aparejo |  | 10d | 2013-12-19 | 2013-12-28 | 15FS+8d, 18FS-3d, 21FS-5d | 0d |  |  |
| 44 | 1.1.8.2 | Esmalte al Agua según de talle en tabiques nuevos |  | 9d | 2014-01-05 | 2014-01-13 | 16FS+8d, 18, 43FS+6d | 0d |  |  |
| 45 | 1.1.8.3 | Preparacion de superficie tabiques existentes. Considera huincha, pasta y aparejo |  | 5d | 2013-12-24 | 2013-12-28 | 43FS-5d | 21d | 0d |  |
| 46 | 1.1.8.4 | Esmalte al Agua blanco en tabiques existentes |  | 6d | 2014-01-05 | 2014-01-10 | 16FS+8d, 18, 43FS+6d | 9d | 0d |  |
| 47 | 1.1.8.5 | Preparacion de superficie cielos de volcanita nuevos. Considera huincha pasta y aparejo |  | 6d | 2014-01-07 | 2014-01-12 | 25FS-3d | 24d |  | start no earlier than 2013-12-19 |
| 48 | 1.1.8.6 | Latex blanco en cielos de nuevos |  | 7d | 2014-01-09 | 2014-01-15 | 25FS-1d | 0d |  |  |
| 49 | 1.1.8.7 | Latex negro en losa a la vista |  | 9d | 2014-01-22 | 2014-01-30 | 102 | 6d |  | start no earlier than 2013-10-26 |
| 50 | 1.1.8.8 | Preparacion de pilares perimetrales existentes |  | 3d | 2014-01-25 | 2014-01-27 | 56 | 0d |  |  |
| 51 | 1.1.8.9 | Esmalte al agua en pilares perimetrales existentes |  | 2d | 2014-01-27 | 2014-01-28 | 50FS-1d | 0d |  | start no earlier than 2013-10-14 |
| 52 | 1.1.8.10 | Barniz poliuretano para puertas enchapadas en cedro |  | 4d | 2014-01-27 | 2014-01-30 | 51FS-2d | 0d |  |  |

| ID | WBS | Task | Duration | Start | Finish | Predecessors | Total slack | Free slack | Constraint |
| --- | --- | --- | --- | --- | --- | --- | --- | --- | --- |
| 53 | 1.1.9 | **CRISTALES** | 28d | 2013-12-27 | 2014-01-24 |  | 12d |  |  |
| 54 | 1.1.9.1 | **TABIQUE VIDRIADO** | 9d | 2014-01-16 | 2014-01-24 |  | 0d |  |  |
| 55 | 1.1.9.1.1 | Rectificación de medidas cristales | 3d | 2014-01-16 | 2014-01-18 | 44, 48 | 0d |  |  |
| 56 | 1.1.9.1.2 | Instalación de perfiles y cristales | 6d | 2014-01-19 | 2014-01-24 | 55 | 0d |  |  |
| 57 | 1.1.9.2 | **PUERTAS** | 19d | 2013-12-27 | 2014-01-15 |  | 21d |  |  |
| 58 | 1.1.9.2.1 | Provision e instalacion de puertas de cristal templado, incluye tirador inox para acceso | 4d | 2014-01-12 | 2014-01-15 | 44FS-2d, 59 | 21d |  | start no earlier than 2013-11-26 |
| 59 | 1.1.9.2.2 | Provision e instalalcion marcos aluminio 40/80 color Mate h=2,50 para puertas enchapadas en cedro | 3d | 2013-12-27 | 2013-12-29 | 43FS-2d | 33d | 12d | start no earlier than 2013-12-02 |
| 60 | 1.1.9.2.3 | Provision e instalacion espejo 4mm para baños canto biselado suspendido 2cm sobre MDF20mm | 4d | 2014-01-04 | 2014-01-07 | 37 | 22d |  | start no earlier than 2013-12-02 |
| 61 | 1.1.10 | **CARPINTERÍA** | 16d | 2014-01-14 | 2014-01-29 |  | 0d |  |  |
| 62 | 1.1.10.1 | **Puertas de Madera** | 16d | 2014-01-14 | 2014-01-29 |  | 0d |  |  |
| 63 | 1.1.10.1.1 | Rectificación de medidas | 1d | 2014-01-14 | 2014-01-14 | 44 | 0d |  | start no earlier than 2013-11-07 |
| 64 | 1.1.10.1.2 | Instalación de Marcos | 3d | 2014-01-24 | 2014-01-26 | 63FS+9d, 18 | 0d |  | start no earlier than 2013-11-16 |
| 65 | 1.1.10.1.3 | Instalación de puertas | 5d | 2014-01-25 | 2014-01-29 | 64FS-2d, 52FS-6d | 0d |  | start no earlier than 2014-01-17 |
| 66 | 1.1.11 | **ELECTRICIDAD Y CABLEADO ESTRUCTURADO** | 62d | 2013-12-03 | 2014-02-03 |  | 2d |  |  |
| 67 | 1.1.11.1 | **Electricidad** | 62d | 2013-12-03 | 2014-02-03 |  | 2d |  |  |
| 68 | 1.1.11.1.1 | Canalizaciones por tabiquería | 9d | 2013-12-03 | 2013-12-11 | 15FS+1d | 2d | 0d |  |
| 69 | 1.1.11.1.2 | Canalizaciones por cielo | 11d | 2013-12-12 | 2013-12-22 | 68 | 10d | 0d |  |
| 70 | 1.1.11.1.3 | Cableado por tabiquería | 9d | 2013-12-23 | 2013-12-31 | 18, 69, 68 | 11d | 0d |  |
| 71 | 1.1.11.1.4 | Cableado por cielo | 8d | 2013-12-23 | 2013-12-30 | 69 | 36d |  |  |
| 72 | 1.1.11.1.5 | Canalización perimetro | 7d | 2013-12-25 | 2013-12-31 | 9, 69FS+2d | 20d | 0d | start no earlier than 2013-10-28 |
| 73 | 1.1.11.1.6 | Cableado perimetro | 7d | 2013-12-30 | 2014-01-06 | 72FS-2d | 30d |  | start no earlier than 2013-11-04 |
| 74 | 1.1.11.1.7 | Canalización de mobiliario | 5d | 2014-01-20 | 2014-01-24 | 109, 72FS-1d | 1d | 0d | start no earlier than 2013-11-04 |
| 75 | 1.1.11.1.8 | Cableado por mobiliario | 5d | 2014-01-24 | 2014-01-28 | 74FS-1d | 1d | 0d | start no earlier than 2013-02-28 |
| 76 | 1.1.11.1.9 | Instalación de luminarias | 10d | 2014-01-16 | 2014-01-25 | 48 | 11d |  | start no earlier than 2013-12-04 |
| 77 | 1.1.11.1.10 | Trabajos en tablero | 6d | 2014-01-29 | 2014-02-03 | 75, 84 | 1d |  | start no earlier than 2014-01-03 |
| 78 | 1.1.11.1.11 | Arranques eléctricos para clima | 5d | 2013-12-23 | 2013-12-27 | 69, 88 | 29d | 0d | start no earlier than 2013-02-14 |
| 79 | 1.1.11.1.12 | Canalización de termostatos | 4d | 2013-12-26 | 2013-12-29 | 78FS-2d, 16 | 29d | 20d | start no earlier than 2013-02-24 |
| 80 | 1.1.11.1.13 | Instalación de interruptores | 4d | 2014-01-02 | 2014-01-05 | 43FS-2d, 70 | 11d | 0d |  |
| 81 | 1.1.11.1.14 | Instalación de face plates | 3d | 2014-01-16 | 2014-01-18 | 80FS+10d | 11d |  |  |

| ID | WBS | Task | Duration | Start | Finish | Predecessors | Total slack | Free slack | Constraint |
| --- | --- | --- | --- | --- | --- | --- | --- | --- | --- |
| 82 | 1.1.11.2 | **Cableado estructural** | 13d | 2014-01-11 | 2014-01-23 |  | 11d |  |  |
| 83 | 1.1.11.2.1 | Instalación Rack | 4d | 2014-01-11 | 2014-01-14 | 46, 31 | 11d | 0d | start no earlier than 2013-02-25 |
| 84 | 1.1.11.2.2 | Trabajos en Rack | 4d | 2014-01-15 | 2014-01-18 | 83 | 11d | 0d | start no earlier than 2013-02-27 |
| 85 | 1.1.11.2.3 | Certificación | 3d | 2014-01-19 | 2014-01-21 | 84 | 12d | 0d | start no earlier than 2013-02-28 |
| 86 | 1.1.11.2.4 | Rotulación | 2d | 2014-01-22 | 2014-01-23 | 85 | 12d |  | start no earlier than 2013-03-01 |
| 87 | 1.1.12 | **AIRE ACONDICIONADO** | 51d | 2013-12-06 | 2014-01-26 |  | 0d |  |  |
| 88 | 1.1.12.1 | Reubicación equipos | 4d | 2013-12-06 | 2013-12-09 | 9FS+15d | 0d |  |  |
| 89 | 1.1.12.2 | Inst. de cañones y tuberias. | 10d | 2013-12-11 | 2013-12-20 | 88FS+1d, 9 | 0d |  | start no earlier than 2013-01-28 |
| 90 | 1.1.12.3 | Red de tubos de desagues | 8d | 2013-12-21 | 2013-12-28 | 88, 89 | 0d |  |  |
| 91 | 1.1.12.4 | Prueba hidráulica | 2d | 2013-12-29 | 2013-12-30 | 90 | 9d | 0d |  |
| 92 | 1.1.12.5 | Instalación de plenos y ductos en hojalatería. | 11d | 2013-12-20 | 2013-12-30 | 88, 89FS-1d | 16d | 7d |  |
| 93 | 1.1.12.6 | Conexión eléctrica de equipos | 7d | 2013-12-28 | 2014-01-04 | 78 | 32d |  | start no earlier than 2013-11-01 |
| 94 | 1.1.12.7 | Instalación de mangas flexibles | 7d | 2013-12-31 | 2014-01-07 | 91 | 9d | 0d |  |
| 95 | 1.1.12.8 | Instalación de difusores y retornos | 12d | 2014-01-08 | 2014-01-19 | 88, 92, 94 | 9d | 0d |  |
| 96 | 1.1.12.9 | Instalación de termostatos | 5d | 2014-01-20 | 2014-01-24 | 79, 88, 94, 95, 46FS-2d | 9d | 0d |  |
| 97 | 1.1.12.10 | Prueba y puesta en marcha | 2d | 2014-01-25 | 2014-01-26 | 88, 91, 96 | 9d |  |  |
| 98 | 1.1.13 | **SEGURIDAD** | 24d | 2014-01-04 | 2014-01-27 |  | 6d |  |  |
| 99 | 1.1.13.1 | **Extinción, deteccion y audio evacuación** | 24d | 2014-01-04 | 2014-01-27 |  | 6d |  |  |
| 100 | 1.1.13.1.1 | Canalización | 7d | 2014-01-04 | 2014-01-10 | 9, 15, 20, 24 | 6d | 0d |  |
| 101 | 1.1.13.1.2 | Cableado | 6d | 2014-01-10 | 2014-01-15 | 100FS-1d | 6d | 0d |  |
| 102 | 1.1.13.1.3 | Instalación de detectores, pulsador y bocina | 6d | 2014-01-16 | 2014-01-21 | 101, 25 | 6d | 0d |  |
| 103 | 1.1.13.1.4 | Reubicar deteror y parlante | 2d | 2014-01-22 | 2014-01-23 | 102 | 9d | 0d |  |
| 104 | 1.1.13.1.5 | Conexión a central | 2d | 2014-01-24 | 2014-01-25 | 103 | 9d | 0d |  |
| 105 | 1.1.13.1.6 | Puesta en marcha | 2d | 2014-01-26 | 2014-01-27 | 104 | 9d |  |  |
| 106 | 1.1.13.1.7 | Reubicación de rociadores | 4d | 2014-01-14 | 2014-01-17 | 48FS-2d | 13d | 0d | start no earlier than 2013-11-17 |
| 107 | 1.1.13.1.8 | Instalacion de rociadores | 9d | 2014-01-15 | 2014-01-23 | 106FS-3d | 13d |  |  |

| ID | WBS | Task | Type | Duration | Start | Finish | Predecessors | Total slack | Constraint |
| --- | --- | --- | --- | --- | --- | --- | --- | --- | --- |
| 108 | 1.1.14 | **MOBILIARIO** |  | 10d | 2014-01-19 | 2014-01-29 |  | 0d |  |
| 109 | 1.1.14.1 | Llegada de muebles a obra | milestone | 0d | 2014-01-19 | 2014-01-19 | 46, 33 | 0d |  |
| 110 | 1.1.14.2 | instalacion de muebles |  | 10d | 2014-01-20 | 2014-01-29 | 109 | 0d |  |
| 111 | 1.1.15 | **LIMPIEZA DE OBRA** |  | 7d | 2014-01-30 | 2014-02-05 |  | 0d |  |
| 112 | 1.1.15.1 | Limpieza de Obra Final |  | 6d | 2014-01-30 | 2014-02-04 | 60, 81, 65, 110 | 0d | start no earlier than 2013-05-12 |
| 113 | 1.1.15.2 | entrega de obra |  | 1d | 2014-02-05 | 2014-02-05 | 112, 41, 97, 86, 77, 65 | 0d | start no earlier than 2013-12-22 |
