# MELI-PROJECT-V03

Schedule from MS Project, 2016-11-25 to 2017-02-07.
Contract

## Calendars

- Estándar: Mon-Fri 09:00-13:00, 15:00-19:00; Sat-Sun 08:00-12:00, 13:00-17:00. Exceptions (off unless hours are given): 2016-11-27 to 2016-11-28, 2016-12-04, 2016-12-08, 2016-12-11, 2016-12-18, 2016-12-24 to 2016-12-25, 2016-12-31 to 2017-01-01.

## Resources

| Resource |
| --- |
| SCP |
| GAMA |
| SCP-FERVI |
| SCP-IM |
| SCP-ARSEC |
| SCP-ARSE |
| SCP-WAAG |
| PROVEEDOR A DESIGNAR |
| INTERIEUR FORMA |
| MANIFESTO |

## Schedule

| ID | WBS | Task | Duration | Start | Finish | Predecessors | Total slack | Free slack | Constraint |
| --- | --- | --- | --- | --- | --- | --- | --- | --- | --- |
| 1 | 1 | **MORAVIA** | 65d | 2016-11-25 | 2017-02-07 |  | 0d |  |  |
| 2 | 1.1 | **Obra civil** | 65d | 2016-11-25 | 2017-02-07 |  | 0d |  |  |
| 3 | 1.1.1 | **DESMONTES Y DEMOLICION** | 13d | 2016-11-25 | 2016-12-12 |  | 0d |  |  |
| 4 | 1.1.1.1 | Retiro de alfombra y acopio | 3d | 2016-11-25 | 2016-11-29 |  | 0d |  | start no earlier than 2016-11-25 |
| 5 | 1.1.1.2 | Desmonte de cielorrasos | 5d | 2016-11-30 | 2016-12-05 | 4 | 0d |  |  |
| 6 | 1.1.1.3 | Desmonte de tabiques y frentes vidriados | 5d | 2016-12-06 | 2016-12-12 | 5 | 0d |  |  |
| 7 | 1.1.2 | ALBAÑILERIA - DC | 7d | 2016-12-09 | 2016-12-16 | 6FS-3d, 5FS-2d | 48d |  |  |
| 8 | 1.1.3 | **TABIQUES DE PLACA DE ROCA DE YESO** | 46d | 2016-12-10 | 2017-01-30 | 6FS-2d | 0d |  |  |
| 9 | 1.1.3.1 | Armado de estructura | 10d | 2016-12-10 | 2016-12-21 | 6SF-5d | 0d |  |  |
| 10 | 1.1.3.2 | Emplacado 1er cara | 10d | 2016-12-16 | 2016-12-28 | 9FS-5d | 27d | 0d |  |
| 11 | 1.1.3.3 | Emplacado 2da cara y terminaciones | 11d | 2017-01-20 | 2017-01-30 | 20 | 0d |  |  |
| 12 | 1.1.4 | **CIELORRASOS PLACA DE ROCA DE YESO** | 32d | 2016-12-26 | 2017-01-28 |  | 5d | 0d |  |
| 13 | 1.1.4.1 | Armado de estructura | 10d | 2016-12-26 | 2017-01-06 | 10FS-3d | 27d |  |  |
| 14 | 1.1.4.2 | Emplacado y terminaciones | 10d | 2017-01-19 | 2017-01-28 | 20FS-15d, 28FS-20d | 5d |  |  |
| 15 | 1.1.5 | **CIELORRASOS DESMONTABLES** | 8d | 2017-01-24 | 2017-01-31 | 12FS-5d | 5d | 0d |  |
| 16 | 1.1.5.1 | Armado estructura | 8d | 2017-01-24 | 2017-01-31 | 28FS-20d, 20 | 5d |  |  |
| 17 | 1.1.5.2 | Colocacion de placas y nivelacion | 5d | 2017-01-24 | 2017-01-28 |  | 8d |  |  |
| 18 | 1.1.6 | INST. SANITARIA | 5d | 2017-01-26 | 2017-01-30 | 8FS-5d | 8d |  | start no earlier than 2016-10-27 |
| 19 | 1.1.7 | **INSTALACION ELECTRICA** | 38d | 2016-12-22 | 2017-02-01 |  | 0d |  |  |
| 20 | 1.1.7.1 | Cañerias | 25d | 2016-12-22 | 2017-01-19 | 9 | 0d |  |  |
| 21 | 1.1.7.2 | Cableado | 16d | 2017-01-11 | 2017-01-26 | 20FS-9d | 8d | 2d |  |
| 22 | 1.1.7.3 | Tableros | 5d | 2017-01-25 | 2017-01-29 | 23FS-8d | 9d |  |  |
| 23 | 1.1.7.4 | Colocacion de artefactos | 4d | 2017-01-29 | 2017-02-01 | 21, 42FS-10d | 6d | 0d |  |
| 24 | 1.1.8 | **CABLEADO ESTRUCTURADO** | 42d | 2016-12-22 | 2017-02-05 |  | 2d |  |  |
| 25 | 1.1.8.1 | Cañerias | 11d | 2016-12-22 | 2017-01-05 | 20SS | 33d |  |  |
| 26 | 1.1.8.2 | Cableado | 7d | 2017-01-30 | 2017-02-05 | 41FS-9d | 2d |  | start no earlier than 2016-11-24 |

| ID | WBS | Task | Duration | Start | Finish | Predecessors | Total slack | Free slack | Constraint |
| --- | --- | --- | --- | --- | --- | --- | --- | --- | --- |
| 27 | 1.1.9 | **AIRE ACONDICIONADO** | 57d | 2016-12-06 | 2017-02-07 |  | 0d |  |  |
| 28 | 1.1.9.1 | Corrimiento de equipos existentes | 57d | 2016-12-06 | 2017-02-07 | 5 | 0d |  |  |
| 29 | 1.1.9.2 | Nuevos equipos | 13d | 2017-01-22 | 2017-02-03 | 41FS-17d | 4d |  | start no earlier than 2016-10-15 |
| 30 | 1.1.10 | **CONTROL DE ACCESOS** | 18d | 2017-01-20 | 2017-02-06 |  | 1d |  |  |
| 31 | 1.1.10.1 | Cañeria y cableado | 5d | 2017-01-20 | 2017-01-24 | 20 | 12d | 11d |  |
| 32 | 1.1.10.2 | Instalación equipamiento | 2d | 2017-02-05 | 2017-02-06 | 31, 41FS-3d | 1d |  |  |
| 33 | 1.1.11 | EXTINCION DE INCENDIO - Modificación de cañerias | 10d | 2017-01-24 | 2017-02-02 | 15FS-8d | 5d |  |  |
| 34 | 1.1.12 | **DETECCION DE INCENDIO** | 16d | 2017-01-20 | 2017-02-04 |  | 3d |  |  |
| 35 | 1.1.12.1 | Cañerias y cableado | 10d | 2017-01-20 | 2017-01-29 | 20 | 7d | 4d |  |
| 36 | 1.1.12.2 | Instalación equipamiento | 2d | 2017-02-03 | 2017-02-04 | 35, 41FS-5d | 3d |  |  |
| 37 | 1.1.13 | Piso tecnico - Nivelacion | 2d | 2017-01-20 | 2017-01-21 | 20 | 9d | 0d |  |
| 38 | 1.1.14 | Provision e instalacion de alfombra | 6d | 2017-01-30 | 2017-02-04 | 43FS-5d, 37 | 1d | 0d |  |
| 39 | 1.1.15 | Provision y colocacion de pisos vinilicos | 3d | 2017-01-18 | 2017-01-20 | 37FS-4d | 16d | 15d |  |
| 40 | 1.1.16 | Provision y colocacion de zocalos | 6d | 2017-01-25 | 2017-01-30 | 43FS-10d | 8d |  | start no earlier than 2016-11-13 |
| 41 | 1.1.17 | **PINTURA** | 16d | 2017-01-23 | 2017-02-07 |  | 0d |  |  |
| 42 | 1.1.17.1 | Cielorrasos | 8d | 2017-01-31 | 2017-02-07 | 43FS-8d, 11 | 0d |  |  |
| 43 | 1.1.17.2 | Tabiques | 12d | 2017-01-23 | 2017-02-03 | 11FS-8d | 1d | 0d |  |
| 44 | 1.1.18 | CARPINTERIA DE MADERA | 2d | 2017-01-25 | 2017-01-26 | 43FS-10d | 7d | 0d |  |
| 45 | 1.1.19 | CRISTALES | 7d | 2017-01-25 | 2017-01-31 | 44FS-2d | 7d |  |  |
| 46 | 1.1.20 | **CCTv** | 15d | 2017-01-20 | 2017-02-03 |  | 4d |  |  |
| 47 | 1.1.20.1 | Cableado | 4d | 2017-01-20 | 2017-01-23 | 20 | 14d | 10d |  |
| 48 | 1.1.20.2 | Instalacion equipamiento | 1d | 2017-02-03 | 2017-02-03 | 47, 41FS-5d | 4d |  |  |
| 49 | 1.1.21 | Muebles Coffe piso 6 | 1d | 2017-02-02 | 2017-02-02 | 43FS-3d, 38FS-3d | 5d |  |  |
| 50 | 1.1.22 | Limpieza de obra | 7d | 2017-01-31 | 2017-02-06 | 38FS-5d, 39FS-5d | 1d |  |  |
| 51 | 1.2 | Armado de Data center | 2d | 2017-02-04 | 2017-02-05 | 39FS-1d, 38FS-1d, 24FS-4d | 2d |  |  |
