# Project Contract Base

Schedule from MS Project, 2018-01-31 to 2018-05-07.

## Calendars

- Contract: Mon-Sat 09:00-13:00, 15:00-19:00; Sun off. Exceptions (off unless hours are given): 2018-02-12 to 2018-02-13 (Carnaval), 2018-03-24 (Dia de la Memoria), 2018-03-29 to 2018-03-30 (Semana Santa), 2018-04-02 (Caidos en Malvinas).

## Schedule

| ID | WBS | Task | Type | Duration | Start | Finish | Predecessors | Total slack | Free slack | Proveedor | Bloques de Ejecución |
| --- | --- | --- | --- | --- | --- | --- | --- | --- | --- | --- | --- |
| 1 | 1 | **TRAFIGURA** |  | 77d | 2018-01-31 | 2018-05-07 |  | 0d |  |  |  |
| 2 | 1.1 | Inicio de Obra | milestone | 0d | 2018-01-31 | 2018-01-31 |  | 0d |  | Contract |  |
| 3 | 1.2 | Aprobación de presupuesto y layout | milestone | 0d | 2018-02-07 | 2018-02-07 | 2FS+7d | 0d |  | Contract |  |
| 4 | 1.3 | Contrataciones e ingresos |  | 10d | 2018-02-08 | 2018-02-21 | 3 | 0d |  | Contract |  |
| 5 | 1.4 | **2 PISO NORTE** |  | 54d | 2018-02-01 | 2018-04-11 |  | 2d |  |  |  |
| 6 | 1.4.1 | **DESMONTES** |  | 13d | 2018-02-01 | 2018-02-17 |  | 2d |  |  |  |
| 7 | 1.4.1.1 | Cerco de obra |  | 1d | 2018-02-07 | 2018-02-07 | 2FS+6d | 2d | 0d | O. Civil |  |
| 8 | 1.4.1.2 | Retiro de alfombra para Acopio |  | 1d | 2018-02-08 | 2018-02-08 | 7 | 2d | 0d | O. Civil |  |
| 9 | 1.4.1.3 | Desmonte de Tabiques divisorios de unidades y baños. AREA NORTE |  | 9d | 2018-02-01 | 2018-02-10 | 2FS+1d, 8FS-7d | 2d | 0d | O. Civil | Desmonte |
| 10 | 1.4.1.4 | Desmontes cielorraso. AREA NORTE |  | 5d | 2018-02-03 | 2018-02-08 | 9FS-7d | 26d | 4d | O. Civil | Desmonte |
| 11 | 1.4.1.5 | Desmonte de elementos varios. (Artefactos sanitarios / mesadas / termotanques / puertas) AREA NORTE |  | 3d | 2018-02-06 | 2018-02-08 | 9FS-5d | 22d | 0d | O. Civil |  |
| 12 | 1.4.1.6 | Picado de pisos en baños y coffe. AREA NORTE |  | 6d | 2018-02-09 | 2018-02-17 | 10FS-4d, 11 | 21d | 0d | O. Civil |  |
| 13 | 1.4.1.7 | Desmonte de Deck |  | 2d | 2018-02-16 | 2018-02-17 | 12FS-2d | 21d | 5d | O. Civil |  |
| 14 | 1.4.2 | **ALBAÑILERIA** |  | 20d | 2018-02-20 | 2018-03-14 |  | 15d |  |  |  |
| 15 | 1.4.2.1 | Ejecución de muretes entre unidades |  | 4d | 2018-02-20 | 2018-02-23 | 9, 52 | 16d | 0d | O. Civil |  |
| 16 | 1.4.2.2 | Colocación de membrana |  | 3d | 2018-02-24 | 2018-02-27 | 15, 13 | 16d | 0d | O. Civil | Bajo Piso |
| 17 | 1.4.2.3 | Reparación de Contrapiso y carpetas. AREA NORTE |  | 3d | 2018-02-27 | 2018-03-01 | 32, 12, 23 | 15d | 0d | O. Civil | Bajo Piso |
| 18 | 1.4.2.4 | Colocación de revestimientos cerámicos. AREA NORTE |  | 7d | 2018-02-27 | 2018-03-06 | 17FS-3d, 342 | 21d | 7d | O. Civil | Baño & Coffee |
| 19 | 1.4.2.5 | Colocación de piso cerámico. AREA NORTE |  | 12d | 2018-03-01 | 2018-03-14 | 17FS-1d | 15d | 0d | O. Civil | Baño & Coffee |
| 20 | 1.4.3 | **INSTALACION SANITARIA** |  | 42d | 2018-02-16 | 2018-04-10 |  | 4d |  |  |  |
| 21 | 1.4.3.1 | Colocación de llaves de paso de corte general. AREA NORTE |  | 1d | 2018-02-16 | 2018-02-16 | 9FS+2d | 13d | 0d | O. Civil |  |
| 22 | 1.4.3.2 | Anulación de instalaciones en desuso. AREA NORTE |  | 3d | 2018-02-17 | 2018-02-20 | 21 | 13d | 0d | O. Civil |  |
| 23 | 1.4.3.3 | Instalación sanitaria para NUCLEO 1 (AREA NORTE) |  | 4d | 2018-02-21 | 2018-02-24 | 31FS-2d, 22 | 13d | 0d | O. Civil | Baño & Coffee |
| 24 | 1.4.3.4 | Instalación sanitaria para NUCLEO 2 (AREA NORTE) |  | 3d | 2018-02-24 | 2018-02-27 | 23FS-1d | 13d | 0d | O. Civil |  |
| 25 | 1.4.3.5 | Drenaje de equipos aire acondicionado |  | 5d | 2018-02-28 | 2018-03-05 | 114FS-2d, 24 | 13d | 0d | O. Civil | Sobre Cielorraso |
| 26 | 1.4.3.6 | Prueba de estanquiedad |  | 1d | 2018-03-06 | 2018-03-06 | 25, 23, 24 | 13d | 0d | O. Civil |  |
| 27 | 1.4.3.7 | Colocación de artefactos y griferías Coffe point |  | 3d | 2018-03-19 | 2018-03-21 | 83 | 15d | 11d | O. Civil |  |
| 28 | 1.4.3.8 | Colocación de artefactos y griferías Coffe point |  | 2d | 2018-04-09 | 2018-04-10 | 82, 27 | 4d |  | O. Civil | Baño & Coffee |

| ID | WBS | Task | Type | Duration | Start | Finish | Predecessors | Total slack | Free slack | Proveedor | Bloques de Ejecución |
| --- | --- | --- | --- | --- | --- | --- | --- | --- | --- | --- | --- |
| 29 | 1.4.4 | **TABIQUES DE PLACA DE ROCA DE YESO** |  | 12d | 2018-02-19 | 2018-03-03 |  | 14d |  |  |  |
| 30 | 1.4.4.1 | Replanteo |  | 1d | 2018-02-19 | 2018-02-19 | 3, 4FS-3d | 14d | 0d | Durlero | Tabiques |
| 31 | 1.4.4.2 | Ejecución de estructura |  | 3d | 2018-02-19 | 2018-02-21 | 30FS-1d | 14d | 0d | Durlero | Tabiques |
| 32 | 1.4.4.3 | Emplaque 1º cara |  | 5d | 2018-02-21 | 2018-02-26 | 31FS-1d | 15d | 0d | Durlero | Tabiques |
| 33 | 1.4.4.4 | Pase instalaciones - Cierre Tabique |  | 1d | 2018-02-26 | 2018-02-26 | 32FS-1d, 43, 93, 94 | 23d | 1d | Durlero | Tabiques |
| 34 | 1.4.4.5 | Emplaque 2º cara con aislación y terminaciones |  | 7d | 2018-02-24 | 2018-03-03 | 33FS-3d, 32FS-3d, 93, 73 | 22d | 0d | Durlero | Tabiques |
| 35 | 1.4.4.6 | Traspaso de Durlock a Pintura (RECEPCION de TABIQUES) |  | 1d | 2018-03-03 | 2018-03-03 | 34FS-1d | 51d |  | Pintor | Terminaciones |
| 36 | 1.4.5 | **CIELORRASO EN PLACAS DE ROCA DE YESO** |  | 13d | 2018-02-27 | 2018-03-13 |  | 13d |  |  |  |
| 37 | 1.4.5.1 | Ejecución de estructura |  | 4d | 2018-02-27 | 2018-03-02 | 32 | 16d | 0d | Durlero | Sobre Cielorraso |
| 38 | 1.4.5.2 | Cierre Cielorraso continuo | milestone | 0d | 2018-03-06 | 2018-03-06 | 37, 95, 97FS-5d, 114, 118FS-9d, 117FS-3d, 25, 26, 41FS-2d | 13d | 0d | Durlero | Sobre Cielorraso |
| 39 | 1.4.5.3 | Emplaque de cielorraso |  | 6d | 2018-03-07 | 2018-03-13 | 37, 38 | 13d | 0d | Durlero | Sobre Cielorraso |
| 40 | 1.4.6 | **HERRERIA** |  | 16d | 2018-02-21 | 2018-03-12 |  | 25d |  |  |  |
| 41 | 1.4.6.1 | Refuerzos para puertas de vidrio |  | 1d | 2018-02-22 | 2018-02-22 | 31 | 25d | 12d | Herrero |  |
| 42 | 1.4.6.2 | Compra de puertas F60 | milestone | 0d | 2018-02-21 | 2018-02-21 | 4 | 44d | 0d | Herrero |  |
| 43 | 1.4.6.3 | Refuerzo para puerta F60 | milestone | 0d | 2018-02-21 | 2018-02-21 | 31 | 26d | 3d | Herrero | Sobre Cielorraso |
| 44 | 1.4.6.4 | Puerta F60 |  | 1d | 2018-03-12 | 2018-03-12 | 43, 42FS+15d | 44d |  | Herrero |  |
| 45 | 1.4.7 | **PINTURA** |  | 16d | 2018-03-07 | 2018-03-26 |  | 13d |  |  |  |
| 46 | 1.4.7.1 | Preparación y pintado de cielorraso junta tomada |  | 6d | 2018-03-07 | 2018-03-13 | 39FS-6d | 13d | 0d | Pintor | Terminaciones |
| 47 | 1.4.7.2 | Preparación y pintado de tabiques |  | 9d | 2018-03-10 | 2018-03-20 | 34FS-4d, 46FS-3d | 13d | 0d | Pintor | Terminaciones |
| 48 | 1.4.7.3 | Pintado de zócalos |  | 3d | 2018-03-17 | 2018-03-20 | 62FS-3d, 47FS-7d | 34d | 1d | Pintor |  |
| 49 | 1.4.7.4 | Preparación de tabiques que reciben empapelado y gráfica |  | 4d | 2018-03-16 | 2018-03-20 | 47FS-4d, 18 | 13d | 0d | Pintor |  |
| 50 | 1.4.7.5 | Terminaciones de pintura |  | 5d | 2018-03-20 | 2018-03-26 | 47FS-3d, 119, 48FS-2d | 33d |  | Pintor | Terminaciones |
| 51 | 1.4.8 | **PISO TECNICO** |  | 15d | 2018-02-16 | 2018-03-05 |  | 0d |  |  |  |
| 52 | 1.4.8.1 | Nivelación general de piso tecnico AREA NORTE |  | 3d | 2018-02-16 | 2018-02-19 | 4FS-5d, 9 | 0d |  |  |  |
| 53 | 1.4.8.2 | Provisión y colocación sector terraza, cortes, calados y ajustes de piso tecnico |  | 3d | 2018-02-28 | 2018-03-02 | 92, 16 | 16d | 0d | Piso Técnico | Bajo Piso |
| 54 | 1.4.8.3 | Cierre de Pisos | milestone | 0d | 2018-03-02 | 2018-03-02 | 92, 53, 15, 98, 99 | 16d | 0d | Piso Técnico | Bajo Piso |
| 55 | 1.4.8.4 | Renivelación Final de Piso |  | 2d | 2018-03-03 | 2018-03-05 | 54 | 16d | 4d | Piso Técnico | Bajo Piso |

Notes:
- 38: instalacion de condctos no verifica con fecha
- 46: Inicio por sector de cielorrasos existentes

| ID | WBS | Task | Type | Duration | Start | Finish | Predecessors | Total slack | Free slack | Proveedor | Bloques de Ejecución |
| --- | --- | --- | --- | --- | --- | --- | --- | --- | --- | --- | --- |
| 56 | 1.4.9 | **ALFOMBRA** |  | 2d | 2018-03-10 | 2018-03-12 |  | 12d |  |  |  |
| 57 | 1.4.9.1 | Instalación de alfombra |  | 2d | 2018-03-10 | 2018-03-12 | 55, 46FS-4d, 67, 344 | 12d | 0d | Alfombrero | Terminaciones |
| 58 | 1.4.10 | **PISO VINILICO** |  | 14d | 2018-02-28 | 2018-03-15 |  | 22d |  |  |  |
| 59 | 1.4.10.1 | Instalación de piso vinilico |  | 2d | 2018-03-14 | 2018-03-15 | 55, 46 | 22d | 0d | Prov. 1 | Terminaciones |
| 60 | 1.4.10.2 | Instalación de piso encastraable para Data Center |  | 1d | 2018-02-28 | 2018-02-28 | 4, 32FS-2d, 345 | 35d |  |  |  |
| 61 | 1.4.11 | **ZOCALOS** |  | 5d | 2018-03-15 | 2018-03-20 |  | 34d |  |  |  |
| 62 | 1.4.11.1 | Instalación de Zócalos |  | 5d | 2018-03-15 | 2018-03-20 | 34FS-3d, 59FS-1d | 34d | 0d | Alfombrero | Terminaciones |
| 63 | 1.4.12 | **CRISTALES** |  | 30d | 2018-03-02 | 2018-04-11 |  | 16d |  |  |  |
| 64 | 1.4.12.1 | Medición de Frentes Vidriados | milestone | 0d | 2018-03-02 | 2018-03-02 | 32, 37 | 16d | 0d | Cristales | Mobiliario de Carpinteria |
| 65 | 1.4.12.2 | Colocación de frentes vidriados y revestimientos de vidrio |  | 5d | 2018-04-06 | 2018-04-11 | 64FS+25d, 38 | 21d | 0d | Cristales | Mobiliario de Carpinteria |
| 66 | 1.4.12.3 | Colocación de puertas de cristal |  | 3d | 2018-04-06 | 2018-04-09 | 64FS+25d, 41, 38 | 23d | 2d |  |  |
| 67 | 1.4.12.4 | Desmonte y Reubicación de frente vidriado Terraza |  | 2d | 2018-03-03 | 2018-03-05 | 64, 16, 53 | 16d | 4d |  |  |
| 68 | 1.4.12.5 | Instalación de espejos en baños |  | 2d | 2018-04-06 | 2018-04-07 | 64FS+25d | 23d | 0d |  |  |
| 69 | 1.4.12.6 | Instalación de mamparas frente a islas de trabajo |  | 2d | 2018-04-09 | 2018-04-10 | 68 | 23d |  |  |  |
| 70 | 1.4.13 | **REVESTIMIENTOS** |  | 5d | 2018-03-21 | 2018-03-27 |  | 13d |  |  |  |
| 71 | 1.4.13.1 | Instalación de empapelado en baños |  | 5d | 2018-03-21 | 2018-03-27 | 49 | 13d |  | Prov. 1 | Terminaciones |
| 72 | 1.4.14 | **CARPINTERIA DE MADERA Y HERRAJES** |  | 8d | 2018-02-22 | 2018-03-02 |  | 22d |  |  |  |
| 73 | 1.4.14.1 | Colocación de puertas placa existentes AREA NORTE |  | 2d | 2018-02-22 | 2018-02-23 | 31 | 22d | 0d |  |  |
| 74 | 1.4.14.2 | Medición de puertas | milestone | 0d | 2018-03-02 | 2018-03-02 | 37, 32 | 52d |  | Carpintero | Terminaciones |
| 75 | 1.4.15 | **MUEBLES ESPECIALES** |  | 25d | 2018-02-21 | 2018-03-22 |  | 4d |  |  |  |
| 76 | 1.4.15.1 | Medición de muebles especiales | milestone | 0d | 2018-02-21 | 2018-02-21 | 4 | 4d | 0d | Carpintero | Terminaciones |
| 77 | 1.4.15.2 | Instalación de muebles Coffe point |  | 2d | 2018-03-17 | 2018-03-19 | 76FS+20d | 4d | 0d | Carpintero | Terminaciones |
| 78 | 1.4.15.3 | Instalación de mueble guardado baños |  | 1d | 2018-03-20 | 2018-03-20 | 77 | 16d | 0d | Carpintero | Terminaciones |
| 79 | 1.4.15.4 | Instalación de bancada y barra coffe point |  | 2d | 2018-03-21 | 2018-03-22 | 78 | 16d |  | Carpintero | Terminaciones |

| ID | WBS | Task | Type | Duration | Start | Finish | Predecessors | Total slack | Free slack | Proveedor | Bloques de Ejecución |
| --- | --- | --- | --- | --- | --- | --- | --- | --- | --- | --- | --- |
| 80 | 1.4.16 | **MESADA** |  | 17d | 2018-03-15 | 2018-04-07 |  | 4d |  |  |  |
| 81 | 1.4.16.1 | Medición de mesadas | milestone | 0d | 2018-03-20 | 2018-03-20 | 77FS+1d | 4d | 0d | Marmolero | Terminaciones |
| 82 | 1.4.16.2 | Instalación de mesada de marmol nuevas en office |  | 2d | 2018-04-06 | 2018-04-07 | 81FS+10d | 4d | 0d | Marmolero | Terminaciones |
| 83 | 1.4.16.3 | Instalación de mesada de marmol en baños a reultilizar |  | 3d | 2018-03-15 | 2018-03-17 | 18, 19 | 15d | 0d | Marmolero | Terminaciones |
| 84 | 1.4.17 | **DETECCION DE INCENDIO** |  | 19d | 2018-02-21 | 2018-03-15 |  | 22d |  |  |  |
| 85 | 1.4.17.1 | Entrega de planos por parte de subcontratista | milestone | 0d | 2018-02-21 | 2018-02-21 | 4 | 23d | 1d |  |  |
| 86 | 1.4.17.2 | Canalización vacia para detección de incendios |  | 7d | 2018-02-23 | 2018-03-02 | 95FS-4d, 85 | 22d | 0d | Dect. | Sobre Cielorraso |
| 87 | 1.4.17.3 | Cableado de detección de incendios. (Subcontartista a definir por el cliente) |  | 3d | 2018-03-09 | 2018-03-12 | 86FS+5d | 22d | 0d |  |  |
| 88 | 1.4.17.4 | Instalación de detectores |  | 3d | 2018-03-13 | 2018-03-15 | 46FS-1d, 87 | 22d |  | Dect. | Sobre Cielorraso |
| 89 | 1.4.18 | **INSTALACION ELECTRICA** |  | 40d | 2018-02-06 | 2018-03-27 |  | 16d |  |  |  |
| 90 | 1.4.18.1 | Electricidad e iluminación de obra |  | 1d | 2018-02-06 | 2018-02-06 | 2FS+5d | 16d | 0d | Electricidad & datos | Desmonte |
| 91 | 1.4.18.2 | Desmonte de instalaciones en desuso |  | 3d | 2018-02-07 | 2018-02-09 | 90 | 68d |  |  |  |
| 92 | 1.4.18.3 | Canalizaciones bajo piso |  | 10d | 2018-02-08 | 2018-02-21 | 90, 9FS-5d, 3 | 15d | 0d | Electricidad & datos | Bajo Piso |
| 93 | 1.4.18.4 | Canalización en tabiques |  | 5d | 2018-02-19 | 2018-02-23 | 31FS-3d | 22d | 0d | Electricidad & datos | Tabiques |
| 94 | 1.4.18.5 | Cañerías Multimedia |  | 2d | 2018-02-22 | 2018-02-23 | 31FS-1d, 93FS-2d | 24d | 1d | Electricidad & datos | Sobre Cielorraso |
| 95 | 1.4.18.6 | Canalizaciones de iluminación |  | 10d | 2018-02-16 | 2018-02-27 | 92FS-5d | 15d | 0d | Electricidad & datos | Sobre Cielorraso |
| 96 | 1.4.18.7 | Canalizaciones para C.A. y CCTV |  | 5d | 2018-02-26 | 2018-03-02 | 95FS-2d | 19d | 0d |  |  |
| 97 | 1.4.18.8 | Cableado de iluminación |  | 7d | 2018-02-24 | 2018-03-03 | 95FS-3d | 15d | 0d | Electricidad & datos | Sobre Cielorraso |
| 98 | 1.4.18.9 | Cableado tensión común y dedicada |  | 5d | 2018-02-21 | 2018-02-26 | 92FS-1d | 18d | 0d | Electricidad & datos | Bajo Piso |
| 99 | 1.4.18.10 | Cableado de Utps para puestos |  | 4d | 2018-02-24 | 2018-02-28 | 92FS-3d, 98FS-2d | 18d | 2d | Electricidad & datos | Bajo Piso |
| 100 | 1.4.18.11 | Cableado de Utps para CCTV Y WI FI |  | 2d | 2018-03-03 | 2018-03-05 | 99FS-3d, 96 | 50d |  |  |  |
| 101 | 1.4.18.12 | Colocación de artefactos de iluminación |  | 5d | 2018-03-17 | 2018-03-22 | 46FS-1d, 347 | 35d |  | Electricidad & datos | Sobre Cielorraso |
| 102 | 1.4.18.13 | Colocación cajas de piso tipo ackermman |  | 3d | 2018-03-13 | 2018-03-15 | 98, 99, 57 | 18d | 6d | Electricidad & datos | Terminaciones |
| 103 | 1.4.18.14 | Alimentadores y montantes |  | 11d | 2018-02-27 | 2018-03-10 | 97FS-5d, 98FS-5d | 15d | 0d | Electricidad & datos |  |
| 104 | 1.4.18.15 | Canalizaciones para alimentación equipos AA y termostatos |  | 3d | 2018-03-03 | 2018-03-06 | 96 | 19d | 4d |  |  |
| 105 | 1.4.18.16 | Alimentación a pie de equipos interiores y exteriores |  | 5d | 2018-03-12 | 2018-03-16 | 103, 38, 104 | 15d | 2d |  |  |
| 106 | 1.4.18.17 | Armado de tableros |  | 7d | 2018-03-09 | 2018-03-16 | 103FS-2d | 19d | 0d | Electricidad & datos | Tablero & Data Center |
| 107 | 1.4.18.18 | Recepción de Tableros |  | 1d | 2018-03-17 | 2018-03-17 | 106 | 19d | 7d | Electricidad & datos | Tablero & Data Center |
| 108 | 1.4.18.19 | Cableado de puestos |  | 10d | 2018-03-12 | 2018-03-22 | 122FS-3d | 12d | 0d | Electricidad & datos | Terminaciones |
| 109 | 1.4.18.20 | Colocación de Faceplate |  | 5d | 2018-03-21 | 2018-03-27 | 108FS-2d, 122 | 12d | 0d | Electricidad & datos | Terminaciones |
| 110 | 1.4.18.21 | Armado de Data center |  | 3d | 2018-03-23 | 2018-03-27 | 108, 102 | 12d | 0d | Electricidad & datos | Tablero & Data Center |
| 111 | 1.4.18.22 | Recepción del Data Center y energía de obra | milestone | 0d | 2018-03-27 | 2018-03-27 | 110, 107, 109 | 12d |  | Electricidad & datos | Tablero & Data Center |

| ID | WBS | Task | Type | Duration | Start | Finish | Predecessors | Total slack | Free slack | Proveedor | Bloques de Ejecución |
| --- | --- | --- | --- | --- | --- | --- | --- | --- | --- | --- | --- |
| 112 | 1.4.19 | **INSTALACION DE AIRE ACONDICIONADO** |  | 30d | 2018-02-19 | 2018-03-26 |  | 13d |  |  |  |
| 113 | 1.4.19.1 | Provisión de equipos de AA | milestone | 0d | 2018-02-19 | 2018-02-19 | 4FS-3d | 13d | 0d |  |  |
| 114 | 1.4.19.2 | Instalación de Equipos de aire PRIVADOS |  | 2d | 2018-02-19 | 2018-02-20 | 113, 3 | 21d | 0d | AA |  |
| 115 | 1.4.19.3 | Adeccuación de extracciones en baños |  | 4d | 2018-02-19 | 2018-02-22 | 113 | 54d | 0d |  |  |
| 116 | 1.4.19.4 | Instalación de Equipos de aire OPEN SPACE |  | 5d | 2018-02-23 | 2018-02-28 | 114, 115 | 54d |  |  |  |
| 117 | 1.4.19.5 | Instalación de cañerias de cobre |  | 7d | 2018-02-21 | 2018-02-28 | 114 | 21d | 8d | AA | Sobre Cielorraso |
| 118 | 1.4.19.6 | Colocación de Conductos |  | 12d | 2018-03-02 | 2018-03-15 | 113FS+10d | 13d | 0d | AA | Sobre Cielorraso |
| 119 | 1.4.19.7 | Instalación de difusores |  | 3d | 2018-03-16 | 2018-03-19 | 118, 46, 39 | 13d | 0d | AA |  |
| 120 | 1.4.19.8 | Puesta en marcha |  | 5d | 2018-03-20 | 2018-03-26 | 119, 105 | 13d |  | AA | Sobre Cielorraso |
| 121 | 1.4.20 | **MOBILIARIO DE LINEA** |  | 4d | 2018-03-10 | 2018-03-14 |  | 12d |  |  |  |
| 122 | 1.4.20.1 | Instalación de puestos de trabajo |  | 4d | 2018-03-10 | 2018-03-14 | 57FS-2d, 357 | 12d | 0d | Prov 2 | Mobiliario & Carp. |
| 123 | 1.5 | **2 PISO SUR** |  | 55d | 2018-01-31 | 2018-04-11 |  | 10d |  |  |  |
| 124 | 1.5.1 | **DESMONTES** |  | 6d | 2018-02-09 | 2018-02-17 |  | 2d |  |  |  |
| 125 | 1.5.1.1 | Cerco de obra |  | 1d | 2018-02-09 | 2018-02-09 | 2FS+8d | 2d | 0d |  |  |
| 126 | 1.5.1.2 | Retiro de alfombra para Acopio |  | 1d | 2018-02-10 | 2018-02-10 | 125 | 2d | 0d |  |  |
| 127 | 1.5.1.3 | Desmonte de Tabiques divisorios de unidades y baños. AREA SUR |  | 3d | 2018-02-14 | 2018-02-16 | 9FS-4d, 126 | 2d | 0d |  |  |
| 128 | 1.5.1.4 | Desmontes cielorraso. AREA SUR |  | 3d | 2018-02-14 | 2018-02-16 | 127FS-3d | 20d | 2d |  |  |
| 129 | 1.5.1.5 | Desmonte de elementos varios. (Artefactos sanitarios / mesadas / termotanques / puertas)AREA SUR |  | 2d | 2018-02-14 | 2018-02-15 | 127FS-3d | 26d | 0d |  |  |
| 130 | 1.5.1.6 | Picado de pisos en baños y coffe. AREA SUR |  | 4d | 2018-02-14 | 2018-02-17 | 129FS-2d | 26d | 8d |  |  |
| 131 | 1.5.2 | **ALBAÑILERIA** |  | 18d | 2018-02-22 | 2018-03-14 |  | 14d |  |  |  |
| 132 | 1.5.2.1 | Ejecución de muretes entre unidades |  | 5d | 2018-02-22 | 2018-02-27 | 127, 165 | 14d | 9d |  |  |
| 133 | 1.5.2.2 | Reparación de Contrapiso y carpetas. AREA SUR |  | 3d | 2018-02-28 | 2018-03-02 | 130, 139 | 18d | 0d |  |  |
| 134 | 1.5.2.3 | Colocación de revestimientos cerámicos. AREA SUR |  | 7d | 2018-03-03 | 2018-03-10 | 133, 342 | 18d | 0d |  |  |
| 135 | 1.5.2.4 | Colocación de piso cerámico. AREA SUR |  | 6d | 2018-03-08 | 2018-03-14 | 133, 134FS-3d | 18d | 14d |  |  |

| ID | WBS | Task | Type | Duration | Start | Finish | Predecessors | Total slack | Free slack | Proveedor | Bloques de Ejecución |
| --- | --- | --- | --- | --- | --- | --- | --- | --- | --- | --- | --- |
| 136 | 1.5.3 | **INSTALACION SANITARIA** |  | 38d | 2018-02-20 | 2018-04-09 |  | 18d |  |  |  |
| 137 | 1.5.3.1 | Colocación de llaves de paso de corte general. AREA SUR |  | 1d | 2018-02-20 | 2018-02-20 | 127FS+2d, 128 | 18d | 0d | O. Civil |  |
| 138 | 1.5.3.2 | Anulación de instalaciones en desuso. AREA SUR |  | 2d | 2018-02-21 | 2018-02-22 | 137 | 18d | 0d | O. Civil |  |
| 139 | 1.5.3.3 | Instalación sanitaria para NUCLEO 3 (AREA SUR) |  | 4d | 2018-02-23 | 2018-02-27 | 138 | 18d | 0d | O. Civil |  |
| 140 | 1.5.3.4 | Adecuación sanitaria para Comedor (AREA SUR) |  | 1d | 2018-02-28 | 2018-02-28 | 139 | 19d | 0d | O. Civil | Baño & Coffee |
| 141 | 1.5.3.5 | Drenaje de equipos aire acondicionado |  | 3d | 2018-03-01 | 2018-03-03 | 140 | 50d | 0d | O. Civil |  |
| 142 | 1.5.3.6 | Prueba de estanqueidad |  | 1d | 2018-03-05 | 2018-03-05 | 140, 141 | 50d |  | O. Civil |  |
| 143 | 1.5.3.7 | Colocación de artefactos y griferías |  | 4d | 2018-04-05 | 2018-04-09 | 190, 191, 135 | 5d |  | O. Civil | Baño & Coffee |
| 144 | 1.5.4 | **TABIQUES DE PLACA DE ROCA DE YESO** |  | 14d | 2018-02-19 | 2018-03-06 |  | 11d |  |  |  |
| 145 | 1.5.4.1 | Replanteo |  | 1d | 2018-02-19 | 2018-02-19 | 3, 4FS-3d | 11d | 0d | Durlero | Tabiques |
| 146 | 1.5.4.2 | Ejecución de estructura |  | 3d | 2018-02-20 | 2018-02-22 | 145 | 11d | 0d | Durlero | Tabiques |
| 147 | 1.5.4.3 | Emplaque 1º cara |  | 5d | 2018-02-21 | 2018-02-26 | 146FS-2d | 11d | 0d | Durlero | Tabiques |
| 148 | 1.5.4.4 | Pase instalaciones - Cierre Tabique |  | 1d | 2018-03-01 | 2018-03-01 | 147FS-1d, 157, 198, 199, 139, 140 | 19d | 0d | Durlero | Tabiques |
| 149 | 1.5.4.5 | Emplaque 2º cara con aislación y terminaciones |  | 7d | 2018-02-27 | 2018-03-06 | 147FS-3d, 148FS-3d, 198, 182 | 19d | 0d | Durlero | Tabiques |
| 150 | 1.5.4.6 | Traspaso de Durlock a Pintura (RECEPCION de TABIQUES) |  | 1d | 2018-03-06 | 2018-03-06 | 149FS-1d | 49d |  | Pintor | Terminaciones |
| 151 | 1.5.5 | **CIELORRASO EN PLACAS DE ROCA DE YESO** |  | 17d | 2018-02-27 | 2018-03-17 |  | 4d |  |  |  |
| 152 | 1.5.5.1 | Ejecución de estructura |  | 4d | 2018-02-27 | 2018-03-02 | 147 | 11d | 0d | Durlero | Sobre Cielorraso |
| 153 | 1.5.5.2 | Cierre Cielorraso continuo | milestone | 0d | 2018-03-12 | 2018-03-12 | 152, 200, 201FS-5d, 216, 217FS-7d, 218, 219, 220 | 4d | 0d | Durlero | Sobre Cielorraso |
| 154 | 1.5.5.3 | Emplaque de cielorraso |  | 6d | 2018-03-12 | 2018-03-17 | 152, 153 | 4d | 0d | Durlero | Sobre Cielorraso |
| 155 | 1.5.6 | **HERRERIA** |  | 12d | 2018-02-05 | 2018-02-21 |  | 25d |  |  |  |
| 156 | 1.5.6.1 | Medicion de ajuste fachada | milestone | 0d | 2018-02-05 | 2018-02-05 | 2FS+5d | 25d | 0d |  |  |
| 157 | 1.5.6.2 | Colocación de ajuste en fachada | milestone | 0d | 2018-02-21 | 2018-02-21 | 156FS+12d | 25d | 6d | Herrero | Sobre Cielorraso |
| 158 | 1.5.7 | **PINTURA** |  | 20d | 2018-03-15 | 2018-04-11 |  | 4d |  |  |  |
| 159 | 1.5.7.1 | Preparación y pintado de cielorraso junta tomada |  | 6d | 2018-03-15 | 2018-03-21 | 154FS-3d | 4d | 0d | Pintor | Terminaciones |
| 160 | 1.5.7.2 | Preparación y pintado de tabiques |  | 10d | 2018-03-20 | 2018-04-04 | 149FS-4d, 159FS-2d | 4d | 0d | Pintor | Terminaciones |
| 161 | 1.5.7.3 | Preparación de tabiques que reciben empapelado y gráfica |  | 4d | 2018-03-28 | 2018-04-04 | 160FS-4d | 4d | 0d |  |  |
| 162 | 1.5.7.4 | Pintado de zócalos |  | 5d | 2018-04-03 | 2018-04-07 | 173FS-2d | 22d | 0d |  |  |
| 163 | 1.5.7.5 | Terminaciones de pintura |  | 5d | 2018-04-06 | 2018-04-11 | 160FS-2d, 162FS-2d, 221 | 22d |  | Pintor | Terminaciones |

| ID | WBS | Task | Type | Duration | Start | Finish | Predecessors | Total slack | Free slack | Proveedor | Bloques de Ejecución |
| --- | --- | --- | --- | --- | --- | --- | --- | --- | --- | --- | --- |
| 164 | 1.5.8 | **PISO TECNICO** |  | 19d | 2018-02-20 | 2018-03-13 |  | 0d |  |  |  |
| 165 | 1.5.8.1 | Nivelación general de piso tecnico AREA SUR |  | 2d | 2018-02-20 | 2018-02-21 | 52 | 0d |  |  |  |
| 166 | 1.5.8.2 | Cierre de Pisos | milestone | 0d | 2018-03-09 | 2018-03-09 | 132, 197, 203, 202 | 5d | 0d | Piso Técnico | Bajo Piso |
| 167 | 1.5.8.3 | Renivelación Final de Piso |  | 3d | 2018-03-10 | 2018-03-13 | 166, 203, 202 | 5d | 1d | Piso Técnico | Bajo Piso |
| 168 | 1.5.9 | **ALFOMBRA** |  | 4d | 2018-03-15 | 2018-03-19 |  | 4d |  |  |  |
| 169 | 1.5.9.1 | Instalación de alfombra |  | 4d | 2018-03-15 | 2018-03-19 | 159FS-6d, 167, 178 | 4d | 0d | Alfombrero | Terminaciones |
| 170 | 1.5.10 | **PISO VINILICO** |  | 3d | 2018-03-22 | 2018-03-26 |  | 14d |  |  |  |
| 171 | 1.5.10.1 | Instalación de piso vinilico |  | 3d | 2018-03-22 | 2018-03-26 | 159, 167, 344 | 14d | 0d | Prov. 1 | Terminaciones |
| 172 | 1.5.11 | **ZOCALOS** |  | 5d | 2018-03-27 | 2018-04-04 |  | 22d |  |  |  |
| 173 | 1.5.11.1 | Instalación de Zócalos |  | 5d | 2018-03-27 | 2018-04-04 | 149, 171 | 22d | 0d | Alfombrero | Terminaciones |
| 174 | 1.5.12 | **CRISTALES** |  | 20d | 2018-03-02 | 2018-03-27 |  | 12d |  |  |  |
| 175 | 1.5.12.1 | Medición de Frentes Vidriados | milestone | 0d | 2018-03-02 | 2018-03-02 | 147, 152 | 12d | 0d | Cristales | Mobiliario de Carpinteria |
| 176 | 1.5.12.2 | Colocación de frentes vidriados y revestimientos de vidrio |  | 5d | 2018-03-21 | 2018-03-27 | 175FS+15d | 26d | 0d | Cristales | Mobiliario de Carpinteria |
| 177 | 1.5.12.3 | Colocación de puertas de cristal |  | 3d | 2018-03-21 | 2018-03-23 | 175FS+15d | 33d | 7d |  |  |
| 178 | 1.5.12.4 | Instalación de espejos en baños |  | 2d | 2018-03-03 | 2018-03-05 | 175 | 12d | 8d |  |  |
| 179 | 1.5.13 | **REVESTIMIENTOS** |  | 5d | 2018-04-05 | 2018-04-10 |  | 4d |  |  |  |
| 180 | 1.5.13.1 | Instalación de empapelado en baños |  | 5d | 2018-04-05 | 2018-04-10 | 161, 135 | 4d |  | Prov. 1 | Terminaciones |
| 181 | 1.5.14 | **CARPINTERIA DE MADERA Y HERRAJES** |  | 2d | 2018-02-23 | 2018-02-24 |  | 20d |  |  |  |
| 182 | 1.5.14.1 | Colocación de puertas placa existentes AREA NORTE Y SUR |  | 2d | 2018-02-23 | 2018-02-24 | 146 | 20d | 1d |  |  |
| 183 | 1.5.15 | **MUEBLES ESPECIALES** |  | 25d | 2018-02-21 | 2018-03-22 |  | 5d |  |  |  |
| 184 | 1.5.15.1 | Medición de muebles especiales | milestone | 0d | 2018-02-21 | 2018-02-21 | 4 | 5d | 0d | Carpintero | Terminaciones |
| 185 | 1.5.15.2 | Instalación de muebles Coffe point |  | 2d | 2018-03-17 | 2018-03-19 | 184FS+20d | 5d | 0d | Carpintero | Terminaciones |
| 186 | 1.5.15.3 | Instalación de mueble guardado |  | 1d | 2018-03-20 | 2018-03-20 | 185 | 16d | 0d | Carpintero | Terminaciones |
| 187 | 1.5.15.4 | Instalación de bancada y barra coffe point |  | 2d | 2018-03-21 | 2018-03-22 | 186 | 16d |  | Carpintero | Terminaciones |

| ID | WBS | Task | Type | Duration | Start | Finish | Predecessors | Total slack | Free slack | Proveedor | Bloques de Ejecución |
| --- | --- | --- | --- | --- | --- | --- | --- | --- | --- | --- | --- |
| 188 | 1.5.16 | **MESADA** |  | 49d | 2018-01-31 | 2018-04-04 |  | 5d |  |  |  |
| 189 | 1.5.16.1 | Medición de mesadas | milestone | 0d | 2018-03-20 | 2018-03-20 | 185FS+1d | 5d | 0d | Marmolero | Terminaciones |
| 190 | 1.5.16.2 | Instalación de mesada de marmol en office |  | 2d | 2018-04-03 | 2018-04-04 | 189FS+7d | 5d | 0d | Marmolero | Terminaciones |
| 191 | 1.5.16.3 | Instalación de mesada de marmol en baños a reultilizar |  | 3d | 2018-01-31 | 2018-02-02 |  | 51d | 46d | Marmolero | Terminaciones |
| 192 | 1.5.17 | **DETECCION DE INCENDIO** |  | 20d | 2018-03-01 | 2018-03-23 |  | 15d |  |  |  |
| 193 | 1.5.17.1 | Canalización y cableado para detección de incendio |  | 7d | 2018-03-01 | 2018-03-08 | 200FS-4d | 25d | 10d | Dect. | Sobre Cielorraso |
| 194 | 1.5.17.2 | Instalación de detectores |  | 3d | 2018-03-21 | 2018-03-23 | 159FS-1d, 193 | 15d |  | Dect. | Sobre Cielorraso |
| 195 | 1.5.18 | **INSTALACION ELECTRICA** |  | 49d | 2018-02-05 | 2018-04-09 |  | 7d |  |  |  |
| 196 | 1.5.18.1 | Electricidad e iluminación de obra |  | 1d | 2018-02-05 | 2018-02-05 | 2FS+4d | 7d | 2d | Electricidad & datos | Desmonte |
| 197 | 1.5.18.2 | Canalizaciones bajo piso |  | 10d | 2018-02-08 | 2018-02-21 | 196, 3 | 5d | 0d | Electricidad & datos | Bajo Piso |
| 198 | 1.5.18.3 | Canalización en tabiques |  | 5d | 2018-02-20 | 2018-02-24 | 146FS-3d | 20d | 0d | Electricidad & datos | Tabiques |
| 199 | 1.5.18.4 | Cañerías Multimedia |  | 2d | 2018-02-23 | 2018-02-24 | 146FS-1d, 198FS-2d | 22d | 3d | Electricidad & datos | Sobre Cielorraso |
| 200 | 1.5.18.5 | Canalizaciones de iluminación y baja tensión |  | 15d | 2018-02-16 | 2018-03-05 | 197FS-5d | 9d | 0d | Electricidad & datos | Sobre Cielorraso |
| 201 | 1.5.18.6 | Cableado de iluminación |  | 7d | 2018-03-02 | 2018-03-09 | 200FS-3d | 10d | 0d | Electricidad & datos | Sobre Cielorraso |
| 202 | 1.5.18.7 | Cableado tensión común y dedicada |  | 8d | 2018-02-21 | 2018-03-01 | 197FS-1d | 5d | 0d | Electricidad & datos | Bajo Piso |
| 203 | 1.5.18.8 | Cableado de Utps |  | 7d | 2018-03-02 | 2018-03-09 | 197FS-1d, 202 | 5d | 0d | Electricidad & datos | Bajo Piso |
| 204 | 1.5.18.9 | Colocación de artefactos de iluminación |  | 5d | 2018-03-21 | 2018-03-27 | 159FS-1d | 32d |  | Electricidad & datos | Sobre Cielorraso |
| 205 | 1.5.18.10 | Colocación cajas de piso tipo ackermman |  | 3d | 2018-03-20 | 2018-03-22 | 169, 202, 203 | 12d | 8d | Electricidad & datos | Terminaciones |
| 206 | 1.5.18.11 | Alimentadores y montantes |  | 11d | 2018-03-05 | 2018-03-16 | 201FS-5d, 202FS-5d | 13d | 0d | Electricidad & datos |  |
| 207 | 1.5.18.12 | Alimentación a pie de equipos interiores y exteriores |  | 5d | 2018-03-17 | 2018-03-22 | 153, 206 | 13d | 2d |  |  |
| 208 | 1.5.18.13 | Armado de tableros |  | 7d | 2018-03-15 | 2018-03-22 | 206FS-2d | 14d | 0d | Electricidad & datos | Tablero & Data Center |
| 209 | 1.5.18.14 | Recepción de Tableros |  | 1d | 2018-03-23 | 2018-03-23 | 208 | 14d | 10d | Electricidad & datos | Tablero & Data Center |
| 210 | 1.5.18.15 | Cableado de puestos |  | 10d | 2018-03-21 | 2018-04-05 | 224FS-3d | 4d | 0d | Electricidad & datos | Terminaciones |
| 211 | 1.5.18.16 | Colocación de Faceplate |  | 5d | 2018-04-04 | 2018-04-09 | 210FS-2d, 224 | 4d | 0d | Electricidad & datos | Terminaciones |
| 212 | 1.5.18.17 | Armado de Data center |  | 3d | 2018-04-06 | 2018-04-09 | 205, 210 | 4d | 0d | Electricidad & datos | Tablero & Data Center |
| 213 | 1.5.18.18 | Recepción del Data Center y energía de obra | milestone | 0d | 2018-04-09 | 2018-04-09 | 209, 211, 212 | 4d |  | Electricidad & datos | Tablero & Data Center |

| ID | WBS | Task | Type | Duration | Start | Finish | Predecessors | Total slack | Free slack | Proveedor | Bloques de Ejecución |
| --- | --- | --- | --- | --- | --- | --- | --- | --- | --- | --- | --- |
| 214 | 1.5.19 | **INSTALACION DE AIRE ACONDICIONADO** |  | 29d | 2018-02-21 | 2018-03-28 |  | 4d |  |  |  |
| 215 | 1.5.19.1 | Provisión de equipos de AA | milestone | 0d | 2018-02-21 | 2018-02-21 | 4 | 4d | 0d |  |  |
| 216 | 1.5.19.2 | Instalación de Equipos de aire |  | 5d | 2018-02-22 | 2018-02-27 | 215, 3 | 4d | 0d | AA |  |
| 217 | 1.5.19.3 | Colocación de Conductos |  | 12d | 2018-03-06 | 2018-03-19 | 216FS+5d, 3 | 4d | 0d | AA | Sobre Cielorraso |
| 218 | 1.5.19.4 | Instalación de cañerias |  | 10d | 2018-02-28 | 2018-03-10 | 216 | 4d | 0d | AA | Sobre Cielorraso |
| 219 | 1.5.19.5 | Drenaje de equipos |  | 5d | 2018-02-26 | 2018-03-02 | 216FS-2d | 10d | 0d | AA | Sobre Cielorraso |
| 220 | 1.5.19.6 | Prueba de estanquiedad |  | 1d | 2018-03-03 | 2018-03-03 | 219 | 10d | 6d | AA |  |
| 221 | 1.5.19.7 | Instalación de difusores |  | 3d | 2018-03-22 | 2018-03-26 | 154, 159, 217 | 11d | 0d | AA |  |
| 222 | 1.5.19.8 | Puesta en marcha |  | 2d | 2018-03-27 | 2018-03-28 | 207, 221 | 11d |  | AA | Sobre Cielorraso |
| 223 | 1.5.20 | **MOBILIARIO DE LINEA** |  | 52d | 2018-01-31 | 2018-04-07 |  | 25d |  |  |  |
| 224 | 1.5.20.1 | Instalación de puestos de trabajo |  | 4d | 2018-03-20 | 2018-03-23 | 169 | 4d | 0d | Prov 2 | Mobiliario & Carp. |
| 225 | 1.5.20.2 | **CORTINAS** |  | 52d | 2018-01-31 | 2018-04-07 |  | 25d |  |  |  |
| 226 | 1.5.20.2.1 | Medición de cortinas |  | 2d | 2018-01-31 | 2018-02-01 |  | 75d |  | Cortinas | Terminaciones |
| 227 | 1.5.20.2.2 | Instalación de cortinas |  | 5d | 2018-04-03 | 2018-04-07 | 159, 160FS-2d | 25d |  | Cortinas | Terminaciones |
| 228 | 1.5.21 | **GRAFICA** |  | 3d | 2018-04-05 | 2018-04-07 |  | 25d |  |  |  |
| 229 | 1.5.21.1 | Colocación de vinilos esmerilados enfrentes vidriados |  | 1d | 2018-04-06 | 2018-04-06 | 176FS+5d, 177 | 26d |  | Gráfica | Terminaciones |
| 230 | 1.5.21.2 | Logos corporeos y grafica sobre tabiques |  | 3d | 2018-04-05 | 2018-04-07 | 161 | 25d |  |  |  |
| 231 | 1.6 | **4 PISO** |  | 60d | 2018-01-31 | 2018-04-17 |  | 9d |  |  |  |
| 232 | 1.6.1 | **DESMONTES** |  | 6d | 2018-02-15 | 2018-02-21 |  | 2d |  |  |  |
| 233 | 1.6.1.1 | Desmonte de Tabiques divisorios de unidades y baños. |  | 3d | 2018-02-15 | 2018-02-17 | 127FS-2d | 2d | 0d | O. Civil | Desmonte |
| 234 | 1.6.1.2 | Desmontes cielorraso |  | 2d | 2018-02-16 | 2018-02-17 | 233FS-2d | 14d | 0d | O. Civil | Desmonte |
| 235 | 1.6.1.3 | Desmonte de elementos varios. (Artefactos sanitarios / mesadas / termotanques / puertas) |  | 2d | 2018-02-16 | 2018-02-17 | 233FS-2d | 17d | 3d | O. Civil |  |
| 236 | 1.6.1.4 | Picado de pisos en baños y coffe. |  | 3d | 2018-02-19 | 2018-02-21 | 234, 235FS-3d | 14d | 5d | O. Civil |  |
| 237 | 1.6.2 | **ALBAÑILERIA** |  | 16d | 2018-02-28 | 2018-03-17 |  | 9d |  |  |  |
| 238 | 1.6.2.1 | Ejecución de muretes entre unidades |  | 3d | 2018-02-28 | 2018-03-02 | 233, 274, 236 | 9d | 0d |  |  |
| 239 | 1.6.2.2 | Reparación de Contrapiso y carpetas |  | 2d | 2018-03-08 | 2018-03-09 | 246, 247, 252FS-3d, 236, 238 | 18d | 0d | O. Civil | Bajo Piso |
| 240 | 1.6.2.3 | Colocación de revestimientos cerámicos Coffes |  | 4d | 2018-03-08 | 2018-03-12 | 239FS-2d, 342 | 20d | 2d | O. Civil | Baño & Coffee |
| 241 | 1.6.2.4 | Colocación de piso cerámico NUCLEO 4 |  | 4d | 2018-03-10 | 2018-03-14 | 239 | 18d | 0d | O. Civil | Baño & Coffee |
| 242 | 1.6.2.5 | Colocación de piso cerámico COFFES |  | 3d | 2018-03-15 | 2018-03-17 | 241, 240 | 39d |  |  |  |

| ID | WBS | Task | Type | Duration | Start | Finish | Predecessors | Total slack | Free slack | Proveedor | Bloques de Ejecución |
| --- | --- | --- | --- | --- | --- | --- | --- | --- | --- | --- | --- |
| 243 | 1.6.3 | **INSTALACION SANITARIA** |  | 37d | 2018-02-19 | 2018-04-06 |  | 7d |  |  |  |
| 244 | 1.6.3.1 | Colocación de llaves de paso de corte general. |  | 1d | 2018-02-19 | 2018-02-19 | 233 | 23d | 0d |  |  |
| 245 | 1.6.3.2 | Anulación de instalaciones en desuso. |  | 3d | 2018-02-20 | 2018-02-22 | 244 | 23d | 0d | O. Civil | Baño & Coffee |
| 246 | 1.6.3.3 | Instalación sanitaria para NUCLEO 4 |  | 5d | 2018-02-23 | 2018-02-28 | 245 | 23d | 0d | O. Civil | Baño & Coffee |
| 247 | 1.6.3.4 | Adecuación para Coffe Recepción |  | 1d | 2018-03-01 | 2018-03-01 | 246, 244 | 23d | 5d | O. Civil | Baño & Coffee |
| 248 | 1.6.3.5 | Colocación de artefactos y griferías |  | 2d | 2018-04-05 | 2018-04-06 | 305, 306 | 7d |  | O. Civil | Baño & Coffee |
| 249 | 1.6.4 | **TABIQUES DE PLACA DE ROCA DE YESO** |  | 27d | 2018-02-16 | 2018-03-19 |  | 9d |  |  |  |
| 250 | 1.6.4.1 | Replanteo |  | 1d | 2018-02-16 | 2018-02-16 | 3, 4FS-5d | 9d |  | Durlero | Tabiques |
| 251 | 1.6.4.2 | Ejecución de estructura |  | 5d | 2018-02-28 | 2018-03-05 | 250, 274 | 0d |  | Durlero | Tabiques |
| 252 | 1.6.4.3 | Emplaque 1º cara |  | 7d | 2018-03-03 | 2018-03-10 | 251FS-2d | 0d |  | Durlero | Tabiques |
| 253 | 1.6.4.4 | Pase instalaciones - Cierre Tabique |  | 1d | 2018-03-10 | 2018-03-10 | 252FS-1d, 263, 264, 313, 314 | 8d | 0d | Durlero | Tabiques |
| 254 | 1.6.4.5 | Emplaque 2º cara con aislación y terminaciones |  | 10d | 2018-03-08 | 2018-03-19 | 252FS-3d, 253FS-3d, 313, 295 | 8d | 0d | Durlero | Tabiques |
| 255 | 1.6.4.6 | Traspaso de Durlock a Pintura (RECEPCION de TABIQUES) |  | 1d | 2018-03-19 | 2018-03-19 | 254FS-1d | 38d |  | Pintor | Terminaciones |
| 256 | 1.6.5 | **CIELORRASO EN PLACAS DE ROCA DE YESO** |  | 12d | 2018-03-12 | 2018-03-26 |  | 0d |  |  |  |
| 257 | 1.6.5.1 | Ejecución de estructura |  | 4d | 2018-03-12 | 2018-03-15 | 252 | 0d |  | Durlero | Sobre Cielorraso |
| 258 | 1.6.5.2 | Cierre Cielorraso continuo | milestone | 0d | 2018-03-15 | 2018-03-15 | 257, 315, 316FS-5d, 331, 332FS-7d, 333, 334, 335 | 0d |  | Durlero | Sobre Cielorraso |
| 259 | 1.6.5.3 | Emplaque de cielorraso |  | 6d | 2018-03-16 | 2018-03-22 | 257, 258 | 0d |  | Durlero | Sobre Cielorraso |
| 260 | 1.6.5.4 | Armado de estructura de desmontable |  | 3d | 2018-03-20 | 2018-03-22 | 254, 258 | 33d | 0d |  |  |
| 261 | 1.6.5.5 | Emplaque de cielorraso desmontable |  | 2d | 2018-03-23 | 2018-03-26 | 260 | 33d |  |  |  |
| 262 | 1.6.6 | **HERRERIA** |  | 30d | 2018-01-31 | 2018-03-08 |  | 36d |  |  |  |
| 263 | 1.6.6.1 | Refuerzos para puertas de vidrio |  | 3d | 2018-03-06 | 2018-03-08 | 251 | 9d | 1d | Herrero | Sobre Cielorraso |
| 264 | 1.6.6.2 | Refuerzo para puerta F60 | milestone | 0d | 2018-03-05 | 2018-03-05 | 251 | 12d | 0d | Herrero | Sobre Cielorraso |
| 265 | 1.6.6.3 | Puerta F60 |  | 1d | 2018-03-06 | 2018-03-06 | 264 | 49d |  |  |  |
| 266 | 1.6.6.4 | Refuerzo + Riel para puertas tipo granero |  | 2d | 2018-01-31 | 2018-02-01 |  | 71d | 54d |  |  |

| ID | WBS | Task | Type | Duration | Start | Finish | Predecessors | Total slack | Free slack | Proveedor | Bloques de Ejecución |
| --- | --- | --- | --- | --- | --- | --- | --- | --- | --- | --- | --- |
| 267 | 1.6.7 | **PINTURA** |  | 20d | 2018-03-20 | 2018-04-16 |  | 0d |  |  |  |
| 268 | 1.6.7.1 | Preparación y pintado de cielorraso junta tomada |  | 6d | 2018-03-20 | 2018-03-27 | 259FS-3d | 0d |  | Pintor | Terminaciones |
| 269 | 1.6.7.2 | Preparación y pintado de tabiques |  | 10d | 2018-03-26 | 2018-04-09 | 254FS-4d, 268FS-2d | 0d |  | Pintor | Terminaciones |
| 270 | 1.6.7.3 | Preparación de tabiques que reciben empapelado y gráfica |  | 4d | 2018-04-05 | 2018-04-09 | 269FS-4d | 0d |  |  |  |
| 271 | 1.6.7.4 | Pintado de zócalos |  | 5d | 2018-04-07 | 2018-04-12 | 286FS-2d | 18d | 0d |  |  |
| 272 | 1.6.7.5 | Terminaciones de pintura |  | 5d | 2018-04-11 | 2018-04-16 | 269FS-2d, 271FS-2d, 336 | 18d |  | Pintor | Terminaciones |
| 273 | 1.6.8 | **PISO TECNICO** |  | 20d | 2018-02-22 | 2018-03-16 |  | 0d |  |  |  |
| 274 | 1.6.8.1 | Nivelación general de piso tecnico |  | 5d | 2018-02-22 | 2018-02-27 | 165 | 0d |  |  |  |
| 275 | 1.6.8.2 | Cortes, calados y ajustes de piso tecnico |  | 3d | 2018-02-23 | 2018-02-26 | 312 | 13d | 4d | Piso Técnico | Bajo Piso |
| 276 | 1.6.8.3 | Cierre de Pisos | milestone | 0d | 2018-03-02 | 2018-03-02 | 238, 275, 312 | 9d | 7d | Piso Técnico | Bajo Piso |
| 277 | 1.6.8.4 | Renivelación Final de Piso |  | 5d | 2018-03-12 | 2018-03-16 | 275, 276, 318, 317 | 2d |  | Piso Técnico | Bajo Piso |
| 278 | 1.6.9 | **ALFOMBRA** |  | 43d | 2018-01-31 | 2018-03-23 |  | 0d |  |  |  |
| 279 | 1.6.9.1 | Compra de Alfombra | milestone | 0d | 2018-01-31 | 2018-01-31 | 2 | 19d |  | Alfombrero | Terminaciones |
| 280 | 1.6.9.2 | Instalación de alfombra |  | 4d | 2018-03-20 | 2018-03-23 | 268FS-6d, 277, 279FS+20d | 0d |  | Alfombrero | Terminaciones |
| 281 | 1.6.10 | **PISO VINILICO** |  | 18d | 2018-03-09 | 2018-04-03 |  | 25d |  |  |  |
| 282 | 1.6.10.1 | Provisión de piso vinilico | milestone | 0d | 2018-03-16 | 2018-03-16 | 4FS+20d | 40d |  |  |  |
| 283 | 1.6.10.2 | Instalación de piso vinilico |  | 3d | 2018-03-28 | 2018-04-03 | 268, 277 | 10d | 0d | Prov. 1 | Terminaciones |
| 284 | 1.6.10.3 | Instalación de piso encastraable para Data Center |  | 1d | 2018-03-09 | 2018-03-09 | 252FS-2d, 4 | 27d |  |  |  |
| 285 | 1.6.11 | **ZOCALOS** |  | 5d | 2018-04-04 | 2018-04-09 |  | 18d |  |  |  |
| 286 | 1.6.11.1 | Instalación de Zócalos |  | 5d | 2018-04-04 | 2018-04-09 | 254, 283 | 18d | 0d | Alfombrero | Terminaciones |
| 287 | 1.6.12 | **CRISTALES** |  | 20d | 2018-03-15 | 2018-04-12 |  | 21d |  |  |  |
| 288 | 1.6.12.1 | Medición de Frentes Vidriados | milestone | 0d | 2018-03-15 | 2018-03-15 | 252, 257 | 21d | 0d | Cristales | Mobiliario de Carpinteria |
| 289 | 1.6.12.2 | Colocación de frentes vidriados y revestimientos de vidrio |  | 5d | 2018-04-07 | 2018-04-12 | 288FS+15d | 21d |  | Cristales | Mobiliario de Carpinteria |
| 290 | 1.6.12.3 | Colocación de puertas de cristal |  | 3d | 2018-04-07 | 2018-04-10 | 263, 288FS+15d | 23d |  |  |  |
| 291 | 1.6.12.4 | Instalación de espejos en baños |  | 1d | 2018-04-07 | 2018-04-07 | 288FS+15d | 25d |  |  |  |

| ID | WBS | Task | Type | Duration | Start | Finish | Predecessors | Total slack | Free slack | Proveedor | Bloques de Ejecución |
| --- | --- | --- | --- | --- | --- | --- | --- | --- | --- | --- | --- |
| 292 | 1.6.13 | **REVESTIMIENTOS** |  | 5d | 2018-04-10 | 2018-04-14 |  | 0d |  |  |  |
| 293 | 1.6.13.1 | Instalación de empapelado en baños. 4 PISO |  | 5d | 2018-04-10 | 2018-04-14 | 270, 369 | 0d |  | Prov. 1 | Terminaciones |
| 294 | 1.6.14 | **CARPINTERIA DE MADERA Y HERRAJES** |  | 33d | 2018-03-06 | 2018-04-17 |  | 8d |  |  |  |
| 295 | 1.6.14.1 | Provisión y colocación de puertas placa Estándar |  | 2d | 2018-03-06 | 2018-03-07 | 251 | 8d | 0d |  |  |
| 296 | 1.6.14.2 | Medición de puertas | milestone | 0d | 2018-03-15 | 2018-03-15 | 252, 257 | 17d | 0d | Carpintero | Terminaciones |
| 297 | 1.6.14.3 | Provisión y colocación de puertas especiales tipo Granero |  | 4d | 2018-04-13 | 2018-04-17 | 296FS+20d, 266 | 17d |  | Carpintero | Terminaciones |
| 298 | 1.6.15 | **MUEBLES ESPECIALES** |  | 25d | 2018-02-21 | 2018-03-22 |  | 7d |  |  |  |
| 299 | 1.6.15.1 | Medición de muebles especiales | milestone | 0d | 2018-02-21 | 2018-02-21 | 4 | 7d | 0d | Carpintero | Terminaciones |
| 300 | 1.6.15.2 | Instalación de muebles Coffe point |  | 2d | 2018-03-17 | 2018-03-19 | 299FS+20d | 7d | 0d | Carpintero | Terminaciones |
| 301 | 1.6.15.3 | Instalación de mueble guardado |  | 1d | 2018-03-20 | 2018-03-20 | 300 | 16d | 0d | Carpintero | Terminaciones |
| 302 | 1.6.15.4 | Instalación de bancada y barra coffe point |  | 2d | 2018-03-21 | 2018-03-22 | 301 | 16d |  | Carpintero | Terminaciones |
| 303 | 1.6.16 | **MESADA** |  | 14d | 2018-03-15 | 2018-04-04 |  | 7d |  |  |  |
| 304 | 1.6.16.1 | Medición de mesadas | milestone | 0d | 2018-03-20 | 2018-03-20 | 300FS+1d | 7d | 0d | Marmolero | Terminaciones |
| 305 | 1.6.16.2 | Instalación de mesada de marmol en office |  | 2d | 2018-04-03 | 2018-04-04 | 304FS+7d | 7d | 0d | Marmolero | Terminaciones |
| 306 | 1.6.16.3 | Instalación de mesada de marmol en baños a reultilizar |  | 3d | 2018-03-15 | 2018-03-17 | 240, 241 | 18d | 11d | Marmolero | Terminaciones |
| 307 | 1.6.17 | **DETECCION DE INCENDIO** |  | 23d | 2018-03-02 | 2018-03-31 |  | 11d |  |  |  |
| 308 | 1.6.17.1 | Canalización y cableado para detección de incendio |  | 7d | 2018-03-02 | 2018-03-09 | 315FS-4d | 24d | 13d | Dect. | Sobre Cielorraso |
| 309 | 1.6.17.2 | Instalación de detectores |  | 3d | 2018-03-27 | 2018-03-31 | 268FS-1d, 308 | 11d |  | Dect. | Sobre Cielorraso |
| 310 | 1.6.18 | **INSTALACION ELECTRICA** |  | 53d | 2018-02-05 | 2018-04-13 |  | 5d |  |  |  |
| 311 | 1.6.18.1 | Electricidad e iluminación de obra |  | 1d | 2018-02-05 | 2018-02-05 | 2FS+4d | 5d | 3d | Electricidad & datos | Desmonte |
| 312 | 1.6.18.2 | Canalizaciones bajo piso |  | 10d | 2018-02-09 | 2018-02-22 | 233FS-6d, 311, 3 | 2d | 0d | Electricidad & datos | Bajo Piso |
| 313 | 1.6.18.3 | Canalización en tabiques |  | 5d | 2018-03-02 | 2018-03-07 | 251FS-3d | 8d | 0d | Electricidad & datos | Tabiques |
| 314 | 1.6.18.4 | Cañerías Multimedia |  | 2d | 2018-03-06 | 2018-03-07 | 251FS-1d, 313FS-2d | 10d | 2d | Electricidad & datos | Sobre Cielorraso |
| 315 | 1.6.18.5 | Canalizaciones de iluminación y baja tensión |  | 15d | 2018-02-17 | 2018-03-06 | 312FS-5d | 8d | 0d | Electricidad & datos | Sobre Cielorraso |
| 316 | 1.6.18.6 | Cableado de iluminación |  | 7d | 2018-03-03 | 2018-03-10 | 315FS-3d | 9d | 0d | Electricidad & datos | Sobre Cielorraso |
| 317 | 1.6.18.7 | Cableado tensión común y dedicada |  | 8d | 2018-02-22 | 2018-03-02 | 312FS-1d | 2d | 0d | Electricidad & datos | Bajo Piso |
| 318 | 1.6.18.8 | Cableado de Utps |  | 7d | 2018-03-03 | 2018-03-10 | 312FS-1d, 317 | 2d | 0d | Electricidad & datos | Bajo Piso |
| 319 | 1.6.18.9 | Colocación de artefactos de iluminación |  | 5d | 2018-03-27 | 2018-04-04 | 268FS-1d | 28d |  | Electricidad & datos | Sobre Cielorraso |
| 320 | 1.6.18.10 | Colocación cajas de piso tipo ackermman |  | 3d | 2018-03-26 | 2018-03-28 | 280, 317, 318 | 8d |  | Electricidad & datos | Terminaciones |
| 321 | 1.6.18.11 | Alimentadores y montantes |  | 11d | 2018-03-06 | 2018-03-17 | 316FS-5d, 317FS-5d | 12d | 0d | Electricidad & datos |  |
| 322 | 1.6.18.12 | Alimentación a pie de equipos interiores y exteriores |  | 5d | 2018-03-19 | 2018-03-23 | 258, 321 | 12d | 5d |  |  |
| 323 | 1.6.18.13 | Armado de tableros |  | 7d | 2018-03-16 | 2018-03-23 | 321FS-2d | 13d | 0d | Electricidad & datos | Tablero & Data Center |
| 324 | 1.6.18.14 | Recepción de Tableros |  | 1d | 2018-03-26 | 2018-03-26 | 323 | 13d |  | Electricidad & datos | Tablero & Data Center |
| 325 | 1.6.18.15 | Cableado de puestos |  | 10d | 2018-03-27 | 2018-04-10 | 339FS-3d | 0d |  | Electricidad & datos | Terminaciones |
| 326 | 1.6.18.16 | Colocación de Faceplate |  | 5d | 2018-04-09 | 2018-04-13 | 325FS-2d, 339 | 0d |  | Electricidad & datos | Terminaciones |
| 327 | 1.6.18.17 | Armado de Data center |  | 3d | 2018-04-11 | 2018-04-13 | 320, 325 | 0d |  | Electricidad & datos | Tablero & Data Center |
| 328 | 1.6.18.18 | Recepción del Data Center y energía de obra | milestone | 0d | 2018-04-13 | 2018-04-13 | 324, 326, 327 | 0d |  | Electricidad & datos | Tablero & Data Center |

| ID | WBS | Task | Type | Duration | Start | Finish | Predecessors | Total slack | Free slack | Proveedor | Bloques de Ejecución |
| --- | --- | --- | --- | --- | --- | --- | --- | --- | --- | --- | --- |
| 329 | 1.6.19 | **INSTALACION DE AIRE ACONDICIONADO** |  | 33d | 2018-02-21 | 2018-04-05 |  | 4d |  |  |  |
| 330 | 1.6.19.1 | Provisión de equipos de AA | milestone | 0d | 2018-02-21 | 2018-02-21 | 4 | 4d | 0d |  |  |
| 331 | 1.6.19.2 | Instalación de Equipos de aire |  | 5d | 2018-02-22 | 2018-02-27 | 330, 3 | 4d | 0d | AA |  |
| 332 | 1.6.19.3 | Colocación de Conductos |  | 12d | 2018-03-06 | 2018-03-19 | 331FS+5d, 3 | 4d |  | AA | Sobre Cielorraso |
| 333 | 1.6.19.4 | Instalación de cañerias |  | 10d | 2018-02-28 | 2018-03-10 | 331 | 4d |  | AA | Sobre Cielorraso |
| 334 | 1.6.19.5 | Drenaje de equipos |  | 5d | 2018-02-26 | 2018-03-02 | 331FS-2d | 10d | 0d | AA | Sobre Cielorraso |
| 335 | 1.6.19.6 | Prueba de estanquiedad |  | 1d | 2018-03-03 | 2018-03-03 | 334 | 10d |  | AA |  |
| 336 | 1.6.19.7 | Instalación de difusores |  | 3d | 2018-03-28 | 2018-04-03 | 259, 268, 332 | 7d | 0d | AA |  |
| 337 | 1.6.19.8 | Puesta en marcha |  | 2d | 2018-04-04 | 2018-04-05 | 322, 336 | 7d |  | AA | Sobre Cielorraso |
| 338 | 1.6.20 | **MOBILIARIO DE LINEA** |  | 4d | 2018-03-26 | 2018-03-31 |  | 0d |  |  |  |
| 339 | 1.6.20.1 | Instalación de puestos de trabajo. 4 PISO |  | 4d | 2018-03-26 | 2018-03-31 | 280, 357 | 0d |  | Prov 2 | Mobiliario & Carp. |
| 340 | 1.7 | **PROVISIONES** |  | 39d | 2018-02-22 | 2018-04-12 |  | 16d |  |  |  |
| 341 | 1.7.1 | **ARTEFACTOS SANITARIOS** |  | 1d | 2018-02-22 | 2018-02-22 |  | 24d |  |  |  |
| 342 | 1.7.1.1 | Provisión de pisos y revestimientos cerámicos |  | 1d | 2018-02-22 | 2018-02-22 | 4 | 24d | 3d |  |  |
| 343 | 1.7.2 | **ALFOMBRA + VINILICO** |  | 9d | 2018-02-27 | 2018-03-09 |  | 21d |  |  |  |
| 344 | 1.7.2.1 | Entrega de Alfombra y piso vinilico | milestone | 0d | 2018-03-09 | 2018-03-09 | 4FS+14d | 12d | 0d | Alfombrero | Terminaciones |
| 345 | 1.7.2.2 | Entrega de piso encastrable | milestone | 0d | 2018-02-27 | 2018-02-27 | 4FS+5d | 35d | 0d |  |  |
| 346 | 1.7.3 | **ARTEFACTOS DE ILUMINACION** |  | 0d | 2018-03-16 | 2018-03-16 |  | 35d |  |  |  |
| 347 | 1.7.3.1 | Provisión de Artefactos de iluminación | milestone | 0d | 2018-03-16 | 2018-03-16 | 4FS+20d | 35d | 0d | Prov. 4 | Sobre Cielorraso |
| 348 | 1.7.4 | **CORTINAS** |  | 25d | 2018-02-26 | 2018-03-28 |  | 12d |  |  |  |
| 349 | 1.7.4.1 | Medición de cortinas | milestone | 0d | 2018-02-26 | 2018-02-26 | 4FS+4d | 12d | 0d | Cortinas | Terminaciones |
| 350 | 1.7.4.2 | Instalación de cortinas |  | 5d | 2018-03-22 | 2018-03-28 | 46, 47FS-3d, 349FS+20d | 12d |  | Cortinas | Terminaciones |
| 351 | 1.7.5 | **GRAFICA** |  | 16d | 2018-03-21 | 2018-04-12 |  | 21d |  |  |  |
| 352 | 1.7.5.1 | Colocación de vinilos esmerilados enfrentes vidriados |  | 1d | 2018-04-12 | 2018-04-12 | 65, 66, 368 | 21d |  | Gráfica | Terminaciones |
| 353 | 1.7.5.2 | Logos corporeos y grafica sosbre tabiques |  | 3d | 2018-03-21 | 2018-03-23 | 49, 368 | 34d |  |  |  |

| ID | WBS | Task | Type | Duration | Start | Finish | Predecessors | Total slack | Free slack | Proveedor | Bloques de Ejecución |
| --- | --- | --- | --- | --- | --- | --- | --- | --- | --- | --- | --- |
| 354 | 1.7.6 | **EQUIPAMIENTO** |  | 1d | 2018-03-19 | 2018-03-19 |  | 19d |  |  |  |
| 355 | 1.7.6.1 | Provisión de mesas, sillas, etc |  | 1d | 2018-03-19 | 2018-03-19 | 4, 57FS+5d | 19d |  | Prov. 4 | Terminaciones |
| 356 | 1.7.7 | **MOBILIARIO DE LINEA** |  | 0d | 2018-03-09 | 2018-03-09 |  | 12d |  |  |  |
| 357 | 1.7.7.1 | Provisión de Mobiliario | milestone | 0d | 2018-03-09 | 2018-03-09 | 3FS+24d | 12d | 0d | Prov 2 | Mobiliario & Carp. |
| 358 | 1.8 | **ENTREGA DE OBRA** |  | 77d | 2018-01-31 | 2018-05-07 |  | 0d |  |  |  |
| 359 | 1.8.1 | Limpieza final de Obra |  | 10d | 2018-01-31 | 2018-02-10 |  | 67d |  |  |  |
| 360 | 1.8.2 | Detalles finales |  | 5d | 2018-04-16 | 2018-04-20 | 248, 283, 284, 293, 302, 309, 79, 71, 355, 59, 60, 88, 28, 143, 171, 180, 187, 194, 350 | 0d |  | Contract | Amortiguador |
| 361 | 1.8.3 | Recepción Interna | milestone | 0d | 2018-04-14 | 2018-04-14 | 326, 327, 328, 337, 360FS-6d, 120, 111, 109, 110, 211, 212, 213, 222 | 0d |  |  |  |
| 362 | 1.8.4 | Recepción Provisoria de Obra | milestone | 0d | 2018-04-19 | 2018-04-19 | 361FS+5d | 0d |  | Contract | Amortiguador |
| 363 | 1.8.5 | Pre entrega FMAX | milestone | 0d | 2018-04-19 | 2018-04-19 | 361FS+5d | 15d |  | Contract | Amortiguador |
| 364 | 1.8.6 | Post Ocupación |  | 15d | 2018-04-20 | 2018-05-07 | 362 | 0d |  | Contract | Amortiguador |
| 365 | 1.8.7 | Recepción definitiva | milestone | 0d | 2018-05-07 | 2018-05-07 | 364 | 0d |  | Contract | Amortiguador |
| 366 | 1.8.8 | **TAREAS A CARGO CLIENTE** |  | 22d | 2018-01-31 | 2018-02-27 |  | 53d |  |  |  |
| 367 | 1.8.8.1 | Mudanza |  | 1d | 2018-01-31 | 2018-01-31 |  | 76d |  |  |  |
| 368 | 1.8.8.2 | Definición Grafica | milestone | 0d | 2018-02-27 | 2018-02-27 | 3FS+15d | 52d | 18d |  |  |
| 369 | 1.8.8.3 | Definicion Empapelado | milestone | 0d | 2018-02-27 | 2018-02-27 | 3FS+15d | 31d |  |  |  |
| 370 | 1.8.8.4 | Dentro del plazo obra no estan contempladas las tareas a realizarse en la oficina 403 (ocupada a la fecha por Trafigura) | milestone | 0d | 2018-01-31 | 2018-01-31 |  | 77d |  |  |  |
