# EDENOR CRONOGRAMA INICIO 28.11.... 09.01.19

Schedule from MS Project, 2018-10-05 to 2019-02-25, costs in $.
SA

## Calendars

- Estándar: Mon-Sun 08:00-12:00, 13:00-17:00.

## Schedule

| ID | WBS | Task | Type | Duration | Start | Finish | Predecessors | Total slack | Free slack | Constraint | Cost |
| --- | --- | --- | --- | --- | --- | --- | --- | --- | --- | --- | --- |
| 1 | 1 | OBRA: EDENOR | manual | 75d | 2018-11-28 | 2019-02-11 |  |  |  |  |  |
| 2 | 2 | **CONTRATO** |  | 34d | 2018-10-05 | 2018-11-08 | 1 |  |  |  |  |
| 3 | 2.1 | Revision del contrato |  | 34d | 2018-10-05 | 2018-11-08 |  | 109d | 0.88d | start no earlier than 2018-10-05 |  |
| 4 | 2.2 | Firma del contrato | milestone | 0d | 2018-11-08 | 2018-11-08 | 3 | 108.12d | 0.12d | finish no earlier than 2018-11-08 |  |
| 5 | 3 | **ALTA DE PROVEEDORES POR PARTE DE SEGURIDAD E HIGIENE DE EDENOR, PARA INGRESO A LA OBRA** |  | 17d | 2018-11-09 | 2018-11-26 | 2 |  |  |  |  |
| 6 | 3.1 | Requerimientos Edenor | milestone | 0d | 2018-11-09 | 2018-11-09 | 4 | 108d | 17d | start no earlier than 2018-11-09 |  |
| 7 | 3.2 | Aprobación Edenor | milestone | 0d | 2018-11-26 | 2018-11-26 | 6 | 91d |  | start no earlier than 2018-11-26 |  |
| 8 | 4 | **INICIO DE OBRA** |  | 0d | 2018-11-28 | 2018-11-28 | 1 |  |  |  | 32,031.59 |
| 9 | 4.1 | **ALBAÑILERIA** |  | 55d | 2018-11-28 | 2019-01-21 |  |  |  |  | 32,031.59 |
| 10 | 4.1.1 | Mampostería ladrillo cerámico hueco, elevación, 12x18x33cm. Incluye revoque de ambos lados |  | 17d | 2018-11-28 | 2018-12-14 |  | 24.12d | 0d | finish no earlier than 2018-12-14 | 32,031.59 |
| 11 | 4.1.2 | Colocación de porcelanato para pisos, incluye adhesivo y empastinado |  | 3d | 2019-01-11 | 2019-01-14 | 13, 10 | 33d | 0d | start no earlier than 2019-01-11 |  |
| 12 | 4.1.3 | Colocación de revestimiento porcelanato para muros y/o tabiques, incluye adhesivo, cantoneras de pvc, y empastinado |  | 7d | 2019-01-14 | 2019-01-21 | 11 | 33d | 3.88d | start no earlier than 2019-01-14 |  |
| 13 | 4.1.4 | Carpeta hidrófuga bajo, en zonas húmedas ( Coffee- Sanitarios ) |  | 2d | 2018-12-15 | 2018-12-16 | 10 | 34.12d | 25.12d |  |  |
| 14 | 5 | **TABIQUES DE PLACA DE ROCA DE YESO** |  | 24d | 2018-12-26 | 2019-01-18 | 10 |  |  |  | 40,926.08 |
| 15 | 5.1 | Estructura y una cara de tabique de placa yeso |  | 5d | 2018-12-26 | 2018-12-31 |  | 13d | 0d |  | 20,463.04 |
| 16 | 5.2 | Segunda placa, para cierre de tabiques |  | 4d | 2019-01-14 | 2019-01-18 | 15, 49 | 2d | 0d | start no earlier than 2019-01-14 | 20,463.04 |
| 17 | 6 | **CIELORRASO EN PLACAS DE ROCA DE YESO Y DESMONTABLE** |  | 12d | 2019-01-07 | 2019-01-18 |  |  |  |  | 48,258.76 |
| 18 | 6.1 | Estructura para cielo raso, Junta tomada y desmontable |  | 5d | 2019-01-07 | 2019-01-12 |  | 5d | 0d | start no earlier than 2019-01-07 | 24,129.38 |
| 19 | 6.2 | Emplacado de cielo raso |  | 6d | 2019-01-17 | 2019-01-22 | 18, 51 | 0.12d | 0d |  | 24,129.38 |
| 20 | 7 | **PISOS VINILICOS / LINOLEUM / PVC / GOMA** |  | 4d | 2019-01-21 | 2019-01-25 | 22, 29 |  |  |  |  |
| 21 | 7.1 | Piso de vinílico auto posante Tarkett simil cemento |  | 4d | 2019-01-21 | 2019-01-25 |  | 27d |  |  |  |
| 22 | 8 | **PISOS TECNICOS** |  | 30d | 2018-12-20 | 2019-01-18 |  |  |  |  |  |
| 23 | 8.1 | Provisión de piso técnico de Acero con Argamasa cementicia. Incluye pedestales regulables 15 cm PT y tornillos |  | 5d | 2018-12-20 | 2018-12-25 |  | 39d | 1.88d |  |  |
| 24 | 8.2 | Nivelación de piso técnico |  | 23d | 2019-01-05 | 2019-01-27 | 23, 50 | 28.12d |  | finish no earlier than 2019-01-18 |  |

| ID | WBS | Task | Type | Duration | Start | Finish | Predecessors | Total slack | Free slack | Constraint | Cost |
| --- | --- | --- | --- | --- | --- | --- | --- | --- | --- | --- | --- |
| 25 | 9 | **REVESTIMIENTOS DE MADERA** |  | 20d | 2019-01-08 | 2019-01-28 | 29, 27 |  |  |  | 5,909.58 |
| 26 | 9.1 | Revestimiento en madera |  | 20d | 2019-01-23 | 2019-02-11 | 19 | 10.12d | 0d |  | 5,909.58 |
| 27 | 10 | **ZOCALOS Y GUARDASILLAS** |  | 4d | 2019-01-31 | 2019-02-04 | 31, 20 |  |  |  | 50,000 |
| 28 | 10.1 | Colocacion de zocalos |  | 4d | 2019-02-02 | 2019-02-05 | 31, 20 | 19.12d |  | start no earlier than 2019-01-24 | 50,000 |
| 29 | 11 | **PINTURA** |  | 19d | 2019-01-14 | 2019-02-02 | 13, 16 |  |  |  | 103,448.9 |
| 30 | 11.1 | Preparación y pintado de losa de HºAº con látex común mediante sistema tinto métrico de losa a la vista |  | 3d | 2019-01-14 | 2019-01-17 |  | 6d | 1d |  | 34,482.97 |
| 31 | 11.2 | Preparación, enduido y pintado de tabiques etc. |  | 10d | 2019-01-23 | 2019-02-01 | 19, 30, 16 | 0.12d | 0d |  | 34,482.97 |
| 32 | 11.3 | Terminaciones de pintura |  | 5d | 2019-02-02 | 2019-02-06 | 31 | 18.12d |  | start no earlier than 2019-01-03 | 34,482.97 |
| 33 | 12 | **CARPINTERIAS DE MADERA Y HERRAJES** |  | 2d | 2019-01-07 | 2019-01-09 |  |  |  |  | 171,334.41 |
| 34 | 12.1 | Puerta placa estandar para pintar |  | 2d | 2019-01-07 | 2019-01-09 |  | 46d |  |  | 171,334.41 |
| 35 | 13 | **HERRERIA** |  | 1d | 2019-02-06 | 2019-02-07 | 33, 18, 38 | 18d |  |  |  |
| 36 | 13.1 | Refuerzo para cristales fijos |  | 1d | 2019-02-06 | 2019-02-07 | 38 | 18d |  |  |  |
| 37 | 13.2 | Refuerzo para puertas de cristal y mampara de cristal |  | 1d | 2019-02-06 | 2019-02-07 | 41 | 18d |  | start no earlier than 2018-12-20 |  |
| 38 | 14 | **CRISTALES** |  | 25d | 2019-01-12 | 2019-02-06 |  | 7d | 0d |  | 36,682.29 |
| 39 | 14.1 | Medición en obra, ajuste de medidas previo a la fabricación | milestone | 0d | 2019-01-12 | 2019-01-12 | 18 | 20d | 0d | start no earlier than 2018-12-09 | 28,395.88 |
| 40 | 14.2 | Fabricación, corte y preparación de cristales, según mediciones |  | 10d | 2019-01-12 | 2019-01-22 | 39 | 20d | 13d | start no earlier than 2018-12-10 | 8,286.41 |
| 41 | 14.3 | Instalación de cristales |  | 2d | 2019-02-04 | 2019-02-06 | 40 | 7d | 0d | start no earlier than 2019-02-04 |  |
| 42 | 15 | **INSTALACIONES SANITARIAS** |  | 6d | 2019-01-22 | 2019-01-27 | 9 | 28.12d |  |  | 4,286.07 |
| 43 | 15.1 | Coffe completo: Incluye agua fría / caliente, desagües cloacales primarios y secundarios, llaves de paso |  | 1d | 2019-01-25 | 2019-01-25 | 44 | 28.12d | 0d |  | 4,286.07 |
| 44 | 15.2 | Núcleo sanitario completo, compuesto por 4 inodoros y 4 bachas. Incluye agua fría / caliente, desagües cloacales primarios y secundarios, llaves de paso |  | 3d | 2019-01-22 | 2019-01-24 | 10 | 28.12d | 0d |  |  |
| 45 | 15.3 | Distribución de agua fría para Dispenser de agua |  | 1d | 2019-01-26 | 2019-01-26 | 43, 44 | 28.12d | 0d |  |  |
| 46 | 15.4 | Drenajes de aires acondicionados |  | 1d | 2019-01-27 | 2019-01-27 | 45 | 28.12d |  |  |  |
| 47 | 15.5 | Instalación de artefactos sanitarios |  | 2d | 2019-01-25 | 2019-01-26 | 44, 12 | 29.12d |  |  |  |
| 48 | 16 | **INSTALACION ELECTRICA** |  | 39.12d | 2018-12-28 | 2019-02-05 |  | 0.12d |  |  | 44,542.69 |
| 49 | 16.1 | Canalizacion en tabiques |  | 3d | 2018-12-31 | 2019-01-03 | 15 | 13d | 11d |  |  |
| 50 | 16.2 | Canalizaciones de bandejas y cañerías bajo piso |  | 8d | 2018-12-28 | 2019-01-04 |  | 0.12d | 0d | finish no earlier than 2019-01-04 | 11,332.12 |
| 51 | 16.3 | Canalizaciones de bandejas y cañerías sobre cielo raso |  | 12d | 2019-01-05 | 2019-01-16 | 50 | 0.12d | 0d |  |  |
| 52 | 16.4 | Canalización y cañería de detección de incendios, alarmas, control de acceso, y cctv |  | 7d | 2019-01-17 | 2019-01-23 | 50, 51 | 32.12d |  | start no earlier than 2018-12-14 |  |
| 53 | 16.5 | Cableado de tensión dedicada para puestos trabajo (proveedor de edenor) |  | 7d | 2019-01-05 | 2019-01-11 | 50 | 41.12d | 21.12d | start no earlier than 2018-12-03 |  |
| 54 | 16.6 | Tablero nuevo para server y puestos dedicados ubicado en piso (proveedor de edenor) |  | 3d | 2019-02-02 | 2019-02-05 | 53, 29 | 20d |  |  | 6,169.35 |
| 55 | 16.7 | Instalación artefactos iluminación comunes |  | 7d | 2019-01-28 | 2019-02-04 | 19, 57 | 21d |  | start no earlier than 2019-01-28 | 11,884.11 |
| 56 | 16.8 | Cableado bajo Piso |  | 2d | 2019-01-18 | 2019-01-20 | 50 | 36d |  | start no earlier than 2019-01-18 | 15,157.11 |
| 57 | 16.9 | Cableado sobre cielo raso y tabiques |  | 2d | 2019-01-21 | 2019-01-23 | 51 | 22d | 0d | start no earlier than 2019-01-21 |  |
| 58 | 16.10 | Canalización y cableado de equipos de aire acondicionado |  | 4d | 2019-01-23 | 2019-01-27 | 57 | 22d | 0d |  |  |
| 59 | 16.11 | Tableros para tensión común, iluminación y aire acondicionado |  | 6d | 2019-01-27 | 2019-02-02 | 58 | 22d | 0d |  |  |

| ID | WBS | Task | Duration | Start | Finish | Predecessors | Total slack | Free slack | Constraint | Cost |
| --- | --- | --- | --- | --- | --- | --- | --- | --- | --- | --- |
| 60 | 17 | **INSTALACIÓN CABLEADO ESTRUCTURADO (proveedor de edenor)** | 17d | 2019-01-07 | 2019-01-24 | 18SS | 28d | 4d |  | 28,924.28 |
| 61 | 17.1 | Canalización de cableado estructurado | 10d | 2019-01-07 | 2019-01-17 |  | 29d | 1d |  |  |
| 62 | 17.2 | Cableado UTP para datos y telefonía Cat6 | 3d | 2019-01-18 | 2019-01-21 | 61 | 28d | 0d | start no earlier than 2019-01-18 |  |
| 63 | 17.3 | Armado de Rack | 3d | 2019-01-21 | 2019-01-24 | 62 | 28d |  | start no earlier than 2018-12-16 | 28,924.28 |
| 64 | 18 | **INSTALACION DETECCION DE INCENDIO** | 4d | 2019-01-28 | 2019-02-01 | 60 |  |  |  |  |
| 65 | 18.1 | Instalación de central de incendios | 1d | 2019-01-28 | 2019-01-29 |  | 24d | 0d |  |  |
| 66 | 18.2 | Cableado | 1d | 2019-01-29 | 2019-01-30 | 65 | 24d | 0d |  |  |
| 67 | 18.3 | Colocación de bases y detectores | 1d | 2019-01-30 | 2019-01-31 | 66 | 24d | 0d |  |  |
| 68 | 18.4 | Puesta en marcha y prueba | 1d | 2019-01-31 | 2019-02-01 | 67 | 24d |  |  |  |
| 69 | 19 | **INSTALACION CONTROL DE ACCESO (proveedor de edenor)** | 5d | 2019-01-31 | 2019-02-05 |  |  |  |  |  |
| 70 | 19.1 | Instalación sofs controlador de acceso | 1d | 2019-01-31 | 2019-02-01 |  | 14d | 0d |  |  |
| 71 | 19.2 | Cableado | 2d | 2019-02-01 | 2019-02-03 | 70 | 14d | 0d |  |  |
| 72 | 19.3 | Instalación de lectoras de huellas, etc. | 1d | 2019-02-03 | 2019-02-04 | 71 | 14d | 0d |  |  |
| 73 | 19.4 | Puesta en marcha y prueba | 1d | 2019-02-04 | 2019-02-05 | 72 | 14d |  |  |  |
| 74 | 20 | **CCTV (proveedor de edenor)** | 6d | 2019-02-05 | 2019-02-11 | 69 | 14d |  |  |  |
| 75 | 20.1 | Instalación de central | 1d | 2019-02-05 | 2019-02-06 |  | 14d | 0d |  |  |
| 76 | 20.2 | Cableado | 2d | 2019-02-06 | 2019-02-08 | 75 | 14d | 0d |  |  |
| 77 | 20.3 | instalación de cámaras | 1d | 2019-02-08 | 2019-02-09 | 76 | 14d | 0d |  |  |
| 78 | 20.4 | Puesta en marcha y prueba | 2d | 2019-02-09 | 2019-02-11 | 77 | 14d |  |  |  |
| 79 | 21 | **DETECCION INTRUSION (proveedor de edenor)** | 4d | 2019-01-28 | 2019-02-01 |  |  |  |  |  |
| 80 | 21.1 | Cableado | 2d | 2019-01-28 | 2019-01-30 |  | 24d | 0d |  |  |
| 81 | 21.2 | instalación de cámaras | 1d | 2019-01-30 | 2019-01-31 | 80 | 24d | 0d |  |  |
| 82 | 21.3 | Puesta en marcha y prueba | 1d | 2019-01-31 | 2019-02-01 | 81 | 24d |  |  |  |
| 83 | 22 | **INSTALACION AIRE ACONDICIONADO Y CALEFACCION** | 20d | 2019-01-14 | 2019-02-03 | 51 |  |  |  |  |
| 84 | 22.1 | Fabricación de ductos según mediciones en obra | 8d | 2019-01-14 | 2019-01-22 | 15 | 31d | 0d |  |  |
| 85 | 22.2 | instalación de Ductos | 3d | 2019-01-22 | 2019-01-25 | 84 | 31d |  | start no earlier than 2018-12-06 |  |
| 86 | 22.3 | Instalación de Cañerías | 2d | 2019-01-12 | 2019-01-14 | 18 | 38d | 14d | start no earlier than 2018-12-06 |  |
| 87 | 22.4 | Montaje de Maquinas | 3d | 2019-01-28 | 2019-01-31 | 86 | 24d | 2d | start no earlier than 2019-01-28 |  |
| 88 | 22.5 | Puesta en marcha | 1d | 2019-02-02 | 2019-02-03 | 59, 87 | 22d |  |  |  |

| ID | WBS | Task | Type | Duration | Start | Finish | Predecessors | Total slack | Free slack | Constraint |
| --- | --- | --- | --- | --- | --- | --- | --- | --- | --- | --- |
| 89 | 23 | **GRAFICA Y SEÑALIZACION** |  | 12d | 2019-01-28 | 2019-02-09 | 38 |  |  |  |
| 90 | 23.1 | Mediciones y fabricación, de graficas y señalizaciones |  | 10d | 2019-01-28 | 2019-02-07 |  | 16d | 0.88d |  |
| 91 | 23.2 | Instalación de graficas y señalizaciones |  | 2d | 2019-02-08 | 2019-02-09 | 90 | 15.12d |  | finish no earlier than 2019-02-09 |
| 92 | 24 | **MUEBLES ESPECIALES** |  | 25d | 2019-01-10 | 2019-02-04 |  |  |  |  |
| 93 | 24.1 | Medicion y Fabricación de muebles especiales |  | 10d | 2019-01-11 | 2019-01-20 |  | 35.12d |  | finish no earlier than 2019-01-20 |
| 94 | 24.2 | Mueble coffe, solo bajo alacena |  | 1d | 2019-01-30 | 2019-01-31 |  | 21.12d | 1d | start no earlier than 2019-01-30 |
| 95 | 24.3 | Mueble coffe, solo alacena. Con puertas en melamina simil madera |  | 0.88d | 2019-02-01 | 2019-02-01 | 94 | 20.12d | 0d | start no earlier than 2019-02-01 |
| 96 | 24.4 | Mueble Meeting. Incluye bancada con asiento y respaldo entelados y tapa en melamna blanca |  | 1d | 2019-02-02 | 2019-02-02 | 95 | 20.12d | 0d | finish no earlier than 2019-02-02 |
| 97 | 24.5 | Lockers. En melamina blanca, con puertas en melamina simil madera |  | 2d | 2019-02-03 | 2019-02-04 | 96 | 20.12d |  | finish no earlier than 2019-02-04 |
| 98 | 25 | **LIMPIEZA DE OBRA** |  | 75d | 2018-11-28 | 2019-02-11 |  |  |  |  |
| 99 | 25.1 | Limpieza de obra diaria |  | 71d | 2018-11-28 | 2019-02-07 |  | 15d | 0d |  |
| 100 | 25.2 | Limpieza de obra final |  | 3d | 2019-02-12 | 2019-02-14 | 99, 26 | 10.12d |  |  |
| 101 | 26 | ENTREGA INTERNA | milestone | 0d | 2019-02-07 | 2019-02-08 |  | 2.88d |  | start no earlier than 2019-02-07 |
| 102 | 27 | ENTREGA PROVISORIA, en pleno funcionamiento y operatividad | milestone | 0d | 2019-02-11 | 2019-02-11 | 101 | 0d |  | start no earlier than 2019-02-11 |
| 103 | 28 | POST OCUPACION |  | 14d | 2019-02-11 | 2019-02-25 | 102 | 0d |  |  |
| 104 | 29 | ENTREGA DEFINITIVA | milestone | 0d | 2019-02-25 | 2019-02-25 | 103 | 0d |  |  |
